# CKM Office Renovation

Schedule from MS Project, 2025-04-07 to 2025-06-21, 7 hours a day, costs in $.
Office Renovation Project
Corporate Knowledge Management

## Calendars

- Standard: Mon-Fri 09:00-13:00, 14:00-17:00; Sat-Sun off. Exceptions (off unless hours are given): 2025-04-18 to 2025-04-21 (Easter), 2025-04-25 (Anzac Day), 2025-05-05 (Labor Day).

## Resources

| Resource | Group | Unit | Rate | Cost per use |
| --- | --- | --- | --- | --- |
| Admin Assistant | Staff |  | 45 |  |
| Carpenter | Contractor |  | 35 |  |
| Carpet | Materials | Lin Metre | 100 |  |
| Carpet Contractor | Contractor |  |  |  |
| Fit-out Consultant | Consultant |  | 65 | 50 |
| Furniture | Asset |  |  |  |
| Gyprock | Material | Sheet | 30 |  |
| IT Consultant | Contractor |  | 80 |  |
| Labourer | Contractor |  | 20 |  |
| Management | Staff |  | 100 |  |
| Network Cable & Points | Asset |  |  |  |
| PABX & Points | Asset |  |  |  |
| Paint | Material | Litre | 50 |  |
| Painter | Contractor |  | 35 |  |
| Personal Computers | Asset |  |  |  |
| Phones | Asset |  |  |  |
| Plaster | Material | Bag | 50 |  |
| Staff | Staff |  | 50 |  |
| Telecommunications consultant | Consultant |  | 60 |  |
| Plasterer | Contractor |  | 35 |  |
| Project Manager | Staff |  | 80 |  |

## Schedule

| ID | WBS | Task | Type | Duration | Start | Finish | Predecessors | Total slack | Free slack | Resources | Work | Cost |
| --- | --- | --- | --- | --- | --- | --- | --- | --- | --- | --- | --- | --- |
| 1 | 1 | **Planning & Research** |  | 15.5d | 2025-04-07 | 2025-05-01 |  | 0.57d |  |  | 73.5h | 6,468 |
| 2 | 1.1 | Develop Requirements Documentation |  | 1d | 2025-04-07 | 2025-04-07 |  | 0.57d | 0d | Project Manager | 7h | 616 |
| 3 | 1.2 | Fit-Out Consultant Research |  | 2d | 2025-04-08 | 2025-04-09 | 2 | 0.57d | 0d | Project Manager | 14h | 1,232 |
| 4 | 1.3 | Telecommunications Consultant Research |  | 2d | 2025-04-10 | 2025-04-11 | 3 | 0.57d | 0d | Project Manager | 14h | 1,232 |
| 5 | 1.4 | IT Network Contractor Research |  | 2d | 2025-04-14 | 2025-04-15 | 4 | 0.57d | 0d | Project Manager | 14h | 1,232 |
| 6 | 1.5 | Building Contractors Research |  | 2d | 2025-04-16 | 2025-04-17 | 5 | 0.57d | 0d | Project Manager | 14h | 1,232 |
| 7 | 1.6 | Submit Requirements to Resources & Request Quotes |  | 1d | 2025-04-22 | 2025-04-22 | 6 | 0.57d | 0d | Project Manager | 7h | 616 |
| 8 | 1.7 | Quotes Received |  | 0.5d | 2025-05-01 | 2025-05-01 | 7FS+5d | 0.57d | 0d | Project Manager | 3.5h | 308 |
| 9 | 1.8 | Planning & Research Complete | milestone | 0d | 2025-05-01 | 2025-05-01 | 8 | 0.57d | 0d |  |  |  |
| 10 | 2 | **Management Approval** |  | 4.14d | 2025-05-01 | 2025-05-08 |  | 0.57d |  |  | 30h | 2,652 |
| 11 | 2.1 | Consolidate Quotes and develop proposal |  | 2d | 2025-05-01 | 2025-05-06 | 9 | 0.57d | 0d | Project Manager | 14h | 1,232 |
| 12 | 2.2 | Develop Project Plan & Durations |  | 2d | 2025-05-06 | 2025-05-08 | 11 | 0.57d | 0d | Project Manager | 14h | 1,232 |
| 13 | 2.3 | Submit Project Plan & Costs to Management |  | 1h | 2025-05-08 | 2025-05-08 | 12 | 0.57d | 0d | Management; Project Manager | 2h | 188 |
| 14 | 2.4 | Management Approval Received | milestone | 0d | 2025-05-08 | 2025-05-08 | 13 | 0.57d | 0d |  |  |  |
| 15 | 3 | **Refit Office** |  | 26.36d | 2025-05-08 | 2025-06-14 |  | 0.57d |  |  | 163h | 60,748.5 |
| 16 | 3.1 | Appoint Resources |  | 1d | 2025-05-08 | 2025-05-09 | 14 | 0.57d | 0d | Project Manager | 7h | 616 |
| 17 | 3.2 | Staff Briefing |  | 1h | 2025-05-09 | 2025-05-09 | 16 | 0.57d | 0d | Project Manager; Staff [700%] | 8h | 438 |
| 18 | 3.3 | **Fit-Out Consultations** |  | 2.5d | 2025-05-09 | 2025-05-14 |  | 0.57d |  |  | 35h | 2,877.5 |
| 19 | 3.3.1 | Office Space / Structure Plan |  | 1d | 2025-05-09 | 2025-05-12 | 17 | 0.57d | 0d | Fit-out Consultant; Project Manager | 14h | 1,121 |
| 20 | 3.3.2 | Select & Order Carpet |  | 0.5d | 2025-05-12 | 2025-05-13 | 19 | 0.57d | 0d | Fit-out Consultant; Project Manager | 7h | 585.5 |
| 21 | 3.3.3 | Select & Order Paint |  | 0.5d | 2025-05-13 | 2025-05-13 | 20 | 0.57d | 0d | Fit-out Consultant; Project Manager | 7h | 585.5 |
| 22 | 3.3.4 | Select & Order Office Furniture |  | 0.5d | 2025-05-13 | 2025-05-14 | 21 | 0.57d | 0d | Fit-out Consultant; Project Manager | 7h | 585.5 |
| 23 | 3.4 | **Telecommuncations Consultations** |  | 2d | 2025-05-14 | 2025-05-16 |  | 0.57d |  |  | 21h | 1,652 |
| 24 | 3.4.1 | Design Telephone Access Points Map |  | 1d | 2025-05-14 | 2025-05-15 | 22 | 0.57d | 0d | Project Manager; Telecommunications consultant | 14h | 1,036 |
| 25 | 3.4.2 | Select & Order New PABX |  | 1d | 2025-05-15 | 2025-05-16 | 24 | 0.57d | 0d | Project Manager | 7h | 616 |

| ID | WBS | Task | Type | Duration | Start | Finish | Predecessors | Total slack | Free slack | Constraint | Resources | Work | Cost |
| --- | --- | --- | --- | --- | --- | --- | --- | --- | --- | --- | --- | --- | --- |
| 26 | 3.5 | **IT Networking Consultations** |  | 9.14d | 2025-05-16 | 2025-05-29 |  | 0.57d |  |  |  | 29h | 22,440 |
| 27 | 3.5.1 | Design Network Access Points Map |  | 2d | 2025-05-16 | 2025-05-20 | 25 | 0.57d | 0d |  | IT Consultant; Project Manager | 14h | 1,176 |
| 28 | 3.5.2 | Select & Order New PCs |  | 1d | 2025-05-20 | 2025-05-21 | 27 | 0.57d | 0d |  | Project Manager | 7h | 616 |
| 29 | 3.5.3 | New PCs Arrive |  | 1h | 2025-05-28 | 2025-05-28 | 28FS+5d | 0.57d | 0d |  | Project Manager | 1h | 20,088 |
| 30 | 3.5.4 | Configure SOE on PCs |  | 1d | 2025-05-28 | 2025-05-29 | 29 | 0.57d |  |  | IT Consultant | 7h | 560 |
| 31 | 3.6 | **Restructure Office** |  | 11d | 2025-05-30 | 2025-06-14 |  | 0d |  |  |  | 63h | 32,725 |
| 32 | 3.6.1 | Erect New Walls |  | 7h | 2025-05-30 | 2025-05-31 | 30 | 0d |  |  | Carpenter [200%] | 14h | 490 |
| 33 | 3.6.2 | Gyprock, Plaster & Finish |  | 14h | 2025-05-31 | 2025-06-05 | 32 | 0d |  |  | Plasterer | 14h | 10,490 |
| 34 | 3.6.3 | Install Network Points |  | 5h | 2025-06-06 | 2025-06-06 | 33FS+1d | 0.71d | 0d |  | IT Consultant | 5h | 400 |
| 35 | 3.6.4 | Install Phone Connections |  | 2h | 2025-06-06 | 2025-06-06 | 34SS | 0.71d |  |  | Telecommunications consultant | 2h | 400 |
| 36 | 3.6.5 | Re-Paint |  | 1d | 2025-06-07 | 2025-06-07 | 35 | 0d |  |  | Painter; Paint [100 Litre] | 7h | 5,245 |
| 37 | 3.6.6 | Carpet |  | 1d | 2025-06-10 | 2025-06-12 | 36FS+1d | 2d | 0d |  | Carpet Contractor; Carpet [100 Lin Metre] | 7h | 15,000 |
| 38 | 3.6.7 | Install New Furniture |  | 1d | 2025-06-12 | 2025-06-14 | 37 | 0d |  |  | Labourer | 7h | 140 |
| 39 | 3.6.8 | Install New PCs |  | 1d | 2025-06-13 | 2025-06-14 | 38FF | 1d | 0d |  | IT Consultant | 7h | 560 |
| 40 | 3.6.9 | Refit Office Complete | milestone | 0d | 2025-06-14 | 2025-06-14 | 39 | 1d | 0.14d |  |  |  |  |
| 41 | 4 | **Office Move** |  | 5d | 2025-06-16 | 2025-06-21 |  | 0d |  |  |  | 302h | 14,984 |
| 42 | 4.1 | Order packing boxes |  | 1h | 2025-06-16 | 2025-06-16 | 38 | 0.86d | 0d |  | Project Manager | 1h | 88 |
| 43 | 4.2 | Staff Pack |  | 1d | 2025-06-16 | 2025-06-17 | 40, 42 | 0.86d | 0d |  | Project Manager; Staff [2000%] | 147h | 7,616 |
| 44 | 4.3 | Staff Move |  | 3d | 2025-06-17 | 2025-06-21 | 43 | 0d |  |  | Staff [2000%]; Labourer | 154h | 7,280 |
| 45 | 4.4 | Office Move Complete | milestone | 0d | 2025-06-21 | 2025-06-21 | 44 | 0d |  | finish no later than 2025-06-25 |  |  |  |
