# CKM Office Renovation

Schedule from MS Project, 2018-05-07 to 2018-07-17, 7 hours a day, costs in $.
Office Renovation Project
Corporate Knowledge Management

## Calendars

- Standard: Mon-Fri 09:00-13:00, 14:00-17:00; Sat-Sun off.

## Resources

| Resource | Group | Unit | Rate | Cost per use |
| --- | --- | --- | --- | --- |
| Admin Assistant | Staff |  | 45 |  |
| Carpenter | Contractor |  | 35 |  |
| Carpet | Materials | Lin Metre | 100 |  |
| Carpet Contractor | Contractor |  |  |  |
| Fit-out Consultant | Consultant |  | 65 | 50 |
| Furniture | Asset |  |  |  |
| Gyprock | Material | Sheet | 30 |  |
| IT Consultant | Contractor |  | 80 |  |
| Labourer | Contractor |  | 20 |  |
| Management | Staff |  | 100 |  |
| Network Cable & Points | Asset |  |  |  |
| PABX & Points | Asset |  |  |  |
| Paint | Material | Litre | 50 |  |
| Painter | Contractor |  | 35 |  |
| Personal Computers | Asset |  |  |  |
| Phones | Asset |  |  |  |
| Plaster | Material | Bag | 50 |  |
| Staff | Staff |  | 50 |  |
| Telecommunications consultant | Consultant |  | 60 |  |
| Plasterer | Contractor |  | 35 |  |
| Project Manager | Staff |  | 80 |  |

## Schedule

| ID | WBS | Task | Type | Duration | Start | Finish | Predecessors | Baseline start | Baseline finish | Baseline duration | Total slack | Free slack | Resources | Work | Cost | Baseline cost |
| --- | --- | --- | --- | --- | --- | --- | --- | --- | --- | --- | --- | --- | --- | --- | --- | --- |
| 1 | 1 | **Planning & Research** |  | 15.5d | 2018-05-07 | 2018-05-28 |  | 2018-05-07 | 2018-05-28 | 15.5d | 0.57d |  |  | 73.5h | 6,468 | 6,468 |
| 2 | 1.1 | Develop Requirements Documentation |  | 1d | 2018-05-07 | 2018-05-07 |  | 2018-05-07 | 2018-05-07 | 1d | 0.57d | 0d | Project Manager | 7h | 616 | 616 |
| 3 | 1.2 | Fit-Out Consultant Research |  | 2d | 2018-05-08 | 2018-05-09 | 2 | 2018-05-08 | 2018-05-09 | 2d | 0.57d | 0d | Project Manager | 14h | 1,232 | 1,232 |
| 4 | 1.3 | Telecommunications Consultant Research |  | 2d | 2018-05-10 | 2018-05-11 | 3 | 2018-05-10 | 2018-05-11 | 2d | 0.57d | 0d | Project Manager | 14h | 1,232 | 1,232 |
| 5 | 1.4 | IT Network Contractor Research |  | 2d | 2018-05-14 | 2018-05-15 | 4 | 2018-05-14 | 2018-05-15 | 2d | 0.57d | 0d | Project Manager | 14h | 1,232 | 1,232 |
| 6 | 1.5 | Building Contractors Research |  | 2d | 2018-05-16 | 2018-05-17 | 5 | 2018-05-16 | 2018-05-17 | 2d | 0.57d | 0d | Project Manager | 14h | 1,232 | 1,232 |
| 7 | 1.6 | Submit Requirements to Resources & Request Quotes |  | 1d | 2018-05-18 | 2018-05-18 | 6 | 2018-05-18 | 2018-05-18 | 1d | 0.57d | 0d | Project Manager | 7h | 616 | 616 |
| 8 | 1.7 | Quotes Received |  | 0.5d | 2018-05-28 | 2018-05-28 | 7FS+5d | 2018-05-28 | 2018-05-28 | 0.5d | 0.57d | 0d | Project Manager | 3.5h | 308 | 308 |
| 9 | 1.8 | Planning & Research Complete | milestone | 0d | 2018-05-28 | 2018-05-28 | 8 | 2018-05-28 | 2018-05-28 | 0d | 0.57d | 0d |  |  |  |  |
| 10 | 2 | **Management Approval** |  | 4.14d | 2018-05-28 | 2018-06-01 |  | 2018-05-28 | 2018-06-01 | 4.14d | 0.57d |  |  | 30h | 2,652 | 2,652 |
| 11 | 2.1 | Consolidate Quotes and develop proposal |  | 2d | 2018-05-28 | 2018-05-30 | 9 | 2018-05-28 | 2018-05-30 | 2d | 0.57d | 0d | Project Manager | 14h | 1,232 | 1,232 |
| 12 | 2.2 | Develop Project Plan & Durations |  | 2d | 2018-05-30 | 2018-06-01 | 11 | 2018-05-30 | 2018-06-01 | 2d | 0.57d | 0d | Project Manager | 14h | 1,232 | 1,232 |
| 13 | 2.3 | Submit Project Plan & Costs to Management |  | 1h | 2018-06-01 | 2018-06-01 | 12 | 2018-06-01 | 2018-06-01 | 1h | 0.57d | 0d | Management; Project Manager | 2h | 188 | 188 |
| 14 | 2.4 | Management Approval Received | milestone | 0d | 2018-06-01 | 2018-06-01 | 13 | 2018-06-01 | 2018-06-01 | 0d | 0.57d | 0d |  |  |  |  |
| 15 | 3 | **Refit Office** |  | 27.36d | 2018-06-01 | 2018-07-10 |  | 2018-06-01 | 2018-07-10 | 27.36d | 0d |  |  | 163h | 60,748.5 | 60,748.5 |
| 16 | 3.1 | Appoint Resources |  | 1d | 2018-06-01 | 2018-06-04 | 14 | 2018-06-01 | 2018-06-04 | 1d | 0.57d | 0d | Project Manager | 7h | 616 | 616 |
| 17 | 3.2 | Staff Briefing |  | 1h | 2018-06-04 | 2018-06-04 | 16 | 2018-06-04 | 2018-06-04 | 1h | 0.57d | 0d | Project Manager; Staff [700%] | 8h | 438 | 438 |
| 18 | 3.3 | **Fit-Out Consultations** |  | 2.5d | 2018-06-04 | 2018-06-07 |  | 2018-06-04 | 2018-06-07 | 2.5d | 0.57d |  |  | 35h | 2,877.5 | 2,877.5 |
| 19 | 3.3.1 | Office Space / Structure Plan |  | 1d | 2018-06-04 | 2018-06-05 | 17 | 2018-06-04 | 2018-06-05 | 1d | 0.57d | 0d | Fit-out Consultant; Project Manager | 14h | 1,121 | 1,121 |
| 20 | 3.3.2 | Select & Order Carpet |  | 0.5d | 2018-06-05 | 2018-06-06 | 19 | 2018-06-05 | 2018-06-06 | 0.5d | 0.57d | 0d | Fit-out Consultant; Project Manager | 7h | 585.5 | 585.5 |
| 21 | 3.3.3 | Select & Order Paint |  | 0.5d | 2018-06-06 | 2018-06-06 | 20 | 2018-06-06 | 2018-06-06 | 0.5d | 0.57d | 0d | Fit-out Consultant; Project Manager | 7h | 585.5 | 585.5 |
| 22 | 3.3.4 | Select & Order Office Furniture |  | 0.5d | 2018-06-06 | 2018-06-07 | 21 | 2018-06-06 | 2018-06-07 | 0.5d | 0.57d | 0d | Fit-out Consultant; Project Manager | 7h | 585.5 | 585.5 |
| 23 | 3.4 | **Telecommuncations Consultations** |  | 2d | 2018-06-07 | 2018-06-11 |  | 2018-06-07 | 2018-06-11 | 2d | 0.57d |  |  | 21h | 1,652 | 1,652 |
| 24 | 3.4.1 | Design Telephone Access Points Map |  | 1d | 2018-06-07 | 2018-06-08 | 22 | 2018-06-07 | 2018-06-08 | 1d | 0.57d | 0d | Project Manager; Telecommunications consultant | 14h | 1,036 | 1,036 |
| 25 | 3.4.2 | Select & Order New PABX |  | 1d | 2018-06-08 | 2018-06-11 | 24 | 2018-06-08 | 2018-06-11 | 1d | 0.57d | 0d | Project Manager | 7h | 616 | 616 |

| ID | WBS | Task | Type | Duration | Start | Finish | Predecessors | Baseline start | Baseline finish | Baseline duration | Total slack | Free slack | Constraint | Resources | Work | Cost | Baseline cost |
| --- | --- | --- | --- | --- | --- | --- | --- | --- | --- | --- | --- | --- | --- | --- | --- | --- | --- |
| 26 | 3.5 | **IT Networking Consultations** |  | 9.14d | 2018-06-11 | 2018-06-22 |  | 2018-06-11 | 2018-06-22 | 9.14d | 0.57d |  |  |  | 29h | 22,440 | 22,440 |
| 27 | 3.5.1 | Design Network Access Points Map |  | 2d | 2018-06-11 | 2018-06-13 | 25 | 2018-06-11 | 2018-06-13 | 2d | 0.57d | 0d |  | IT Consultant; Project Manager | 14h | 1,176 | 1,176 |
| 28 | 3.5.2 | Select & Order New PCs |  | 1d | 2018-06-13 | 2018-06-14 | 27 | 2018-06-13 | 2018-06-14 | 1d | 0.57d | 0d |  | Project Manager | 7h | 616 | 616 |
| 29 | 3.5.3 | New PCs Arrive |  | 1h | 2018-06-21 | 2018-06-21 | 28FS+5d | 2018-06-21 | 2018-06-21 | 1h | 0.57d | 0d |  | Project Manager | 1h | 20,088 | 20,088 |
| 30 | 3.5.4 | Configure SOE on PCs |  | 1d | 2018-06-21 | 2018-06-22 | 29 | 2018-06-21 | 2018-06-22 | 1d | 0.57d |  |  | IT Consultant | 7h | 560 | 560 |
| 31 | 3.6 | **Restructure Office** |  | 12d | 2018-06-23 | 2018-07-10 |  | 2018-06-23 | 2018-07-10 | 12d | 0d |  |  |  | 63h | 32,725 | 32,725 |
| 32 | 3.6.1 | Erect New Walls |  | 7h | 2018-06-23 | 2018-06-23 | 30 | 2018-06-23 | 2018-06-23 | 7h | 0d |  |  | Carpenter [200%] | 14h | 490 | 490 |
| 33 | 3.6.2 | Gyprock, Plaster & Finish |  | 14h | 2018-06-25 | 2018-06-29 | 32 | 2018-06-25 | 2018-06-29 | 14h | 0d |  |  | Plasterer | 14h | 10,490 | 10,490 |
| 34 | 3.6.3 | Install Network Points |  | 5h | 2018-07-02 | 2018-07-02 | 33FS+1d | 2018-07-02 | 2018-07-02 | 5h | 0.71d | 0d |  | IT Consultant | 5h | 400 | 400 |
| 35 | 3.6.4 | Install Phone Connections |  | 2h | 2018-07-02 | 2018-07-02 | 34SS | 2018-07-02 | 2018-07-02 | 2h | 0.71d |  |  | Telecommunications consultant | 2h | 400 | 400 |
| 36 | 3.6.5 | Re-Paint |  | 1d | 2018-07-03 | 2018-07-05 | 35 | 2018-07-03 | 2018-07-05 | 1d | 0d |  |  | Painter; Paint [100 Litre] | 7h | 5,245 | 5,245 |
| 37 | 3.6.6 | Carpet |  | 1d | 2018-07-06 | 2018-07-07 | 36FS+1d | 2018-07-06 | 2018-07-07 | 1d | 0d |  |  | Carpet Contractor; Carpet [100 Lin Metre] | 7h | 15,000 | 15,000 |
| 38 | 3.6.7 | Install New Furniture |  | 1d | 2018-07-07 | 2018-07-10 | 37 | 2018-07-07 | 2018-07-10 | 1d | 0d |  |  | Labourer | 7h | 140 | 140 |
| 39 | 3.6.8 | Install New PCs |  | 1d | 2018-07-10 | 2018-07-10 | 38 | 2018-07-10 | 2018-07-10 | 1d | 0d |  |  | IT Consultant | 7h | 560 | 560 |
| 40 | 3.6.9 | Refit Office Complete | milestone | 0d | 2018-07-10 | 2018-07-10 | 39 | 2018-07-10 | 2018-07-10 | 0d | 0d |  |  |  |  |  |  |
| 41 | 4 | **Office Move** |  | 5d | 2018-07-10 | 2018-07-17 |  | 2018-07-10 | 2018-07-17 | 5d | 0d |  |  |  | 306h | 15,064 | 15,064 |
| 42 | 4.1 | Order packing boxes |  | 1h | 2018-07-10 | 2018-07-10 | 38 | 2018-07-10 | 2018-07-10 | 1h | 0.86d |  |  | Project Manager | 1h | 88 | 88 |
| 43 | 4.2 | Staff Pack |  | 1d | 2018-07-11 | 2018-07-11 | 40, 42 | 2018-07-11 | 2018-07-11 | 1d | 0d |  |  | Project Manager; Staff [2000%] | 147h | 7,616 | 7,616 |
| 44 | 4.3 | Staff Move |  | 3.57d | 2018-07-12 | 2018-07-17 | 43 | 2018-07-12 | 2018-07-17 | 3.57d | 0d |  |  | Staff [2000%]; Labourer | 158h | 7,360 | 7,360 |
| 45 | 4.4 | Office Move Complete | milestone | 0d | 2018-07-17 | 2018-07-17 | 44 | 2018-07-17 | 2018-07-17 | 0d | 0d |  | finish no later than 2018-07-20 |  |  |  |  |
