# New House Template

Schedule from MS Project, 2018-05-07 to 2018-08-06.
Templates

## Calendars

- Standard: Mon-Fri 08:00-12:00, 13:00-17:00; Sat-Sun off.

## Resources

| Resource |
| --- |
| Architect |
| Drafter |
| Accountant |
| Admin Assistant |
| Supervisor |
| Labourer |
| Equipment Operators |
| Drivers |
| Carpenter |
| Trade Assistants |
| Electrical Subcontractor |
| Plumbing Subcontractor |
| Roofing Subcontractor |
| Building Inspector |
| Concreting Subcontractor |
| Grader |
| Truck |
| Digger |
| Owner |
| Cabinetmaker |
| Inspector |
| Bricklaying Subcontractor |
| Plastering Contractor |
| Painting Contractor |
| Carpet Contractor |

## Schedule

| ID | WBS | Task | Type | Duration | Start | Finish | Predecessors | Total slack | Free slack | Resources | Work |
| --- | --- | --- | --- | --- | --- | --- | --- | --- | --- | --- | --- |
| 1 | 1 | **Design & Approvals** |  | 11d | 2018-05-07 | 2018-05-21 |  | 1d |  |  | 96h |
| 2 | 1.1 | Architectural Plans |  | 2w | 2018-05-07 | 2018-05-18 |  | 1d | 0d | Architect | 80h |
| 3 | 1.2 | Council approval |  | 1d | 2018-05-21 | 2018-05-21 | 2 | 1d | 0d | Admin Assistant; Owner | 16h |
| 4 | 2 | **Site Clearing and Setup** |  | 7d | 2018-06-11 | 2018-06-19 |  | 1d |  |  | 384h |
| 5 | 2.1 | Site preparation |  | 3d | 2018-06-11 | 2018-06-13 | 3FS+14d | 1d | 0d | Grader; Drivers; Labourer | 72h |
| 6 | 2.2 | Delivery of Materials |  | 1d | 2018-06-11 | 2018-06-11 | 5SS | 40d |  | Truck [200%]; Drivers [200%] | 32h |
| 7 | 2.3 | Lay Foundations |  | 2d | 2018-06-14 | 2018-06-15 | 5 | 1d | 0d | Labourer [400%]; Concreting Subcontractor; Trade Assistants [800%] | 208h |
| 8 | 2.4 | External Plumbing |  | 1d | 2018-06-18 | 2018-06-18 | 7 | 1d | 0d | Plumbing Subcontractor; Labourer; Trade Assistants | 24h |
| 9 | 2.5 | Pour foundation slab |  | 1d | 2018-06-19 | 2018-06-19 | 8 | 1d | 0d | Labourer [400%]; Concreting Subcontractor; Trade Assistants | 48h |
| 10 | 3 | **Framing and Externals** |  | 12d | 2018-06-20 | 2018-07-05 |  | 0d |  |  | 592h |
| 11 | 3.1 | Erect house frame |  | 3d | 2018-06-20 | 2018-06-22 | 9 | 1d | 0d | Carpenter [400%]; Labourer [200%]; Trade Assistants [400%] | 240h |
| 12 | 3.2 | Roofing tiles |  | 4.12d | 2018-06-25 | 2018-06-28 | 11 | 0d |  | Roofing Subcontractor; Labourer [200%] | 72h |
| 13 | 3.3 | Erect Brick Walls |  | 5d | 2018-06-29 | 2018-07-05 | 12 | 0d |  | Bricklaying Subcontractor; Labourer [200%]; Trade Assistants [400%] | 280h |
| 14 | 4 | **Internal Fitout** |  | 22d | 2018-07-06 | 2018-08-06 |  | 0d |  |  | 520h |
| 15 | 4.1 | Fit Windows & Doors |  | 2d | 2018-07-06 | 2018-07-09 | 13 | 0d |  | Carpenter [200%]; Trade Assistants [200%] | 64h |
| 16 | 4.2 | Electrical Cables |  | 1d | 2018-07-10 | 2018-07-10 | 15 | 0d |  | Electrical Subcontractor | 8h |
| 17 | 4.3 | Internal Plumbing |  | 1d | 2018-07-10 | 2018-07-10 | 16SS | 0d |  | Plumbing Subcontractor; Trade Assistants [200%] | 24h |
| 18 | 4.4 | Plaster Walls |  | 5d | 2018-07-11 | 2018-07-17 | 17 | 0d |  | Plastering Contractor | 40h |
| 19 | 4.5 | Internal Doors and Trim |  | 4d | 2018-07-18 | 2018-07-23 | 18 | 0d |  | Carpenter [200%]; Trade Assistants [400%] | 192h |
| 20 | 4.6 | Install Kitchen |  | 2d | 2018-07-24 | 2018-07-25 | 19 | 0d |  | Cabinetmaker; Trade Assistants [200%] | 48h |
| 21 | 4.7 | Install Bathroom |  | 2d | 2018-07-24 | 2018-07-25 | 20SS | 0d |  | Plumbing Subcontractor; Trade Assistants [200%]; Labourer | 64h |
| 22 | 4.8 | Final Electrical Fittings |  | 2d | 2018-07-26 | 2018-07-27 | 21 | 0d |  | Electrical Subcontractor | 16h |
| 23 | 4.9 | Final Plumbing Fittings |  | 2d | 2018-07-26 | 2018-07-27 | 22SS | 0d |  | Plumbing Subcontractor | 16h |
| 24 | 4.10 | Paint |  | 5d | 2018-07-30 | 2018-08-03 | 23 | 0d |  | Painting Contractor | 40h |
| 25 | 4.11 | Carpet laying |  | 1d | 2018-08-06 | 2018-08-06 | 24 | 0d |  | Carpet Contractor | 8h |
| 26 | 4.12 | Practical Completion | milestone | 0d | 2018-08-06 | 2018-08-06 | 25 | 0d |  |  |  |
