# Best selling Novel Schedule

Schedule from MS Project, 2018-05-07 to 2019-01-08.

## Calendars

- Standard: Mon-Fri 08:00-12:00, 13:00-17:00; Sat-Sun off.
- Monday-Wednesday: Mon-Wed 08:00-12:00, 13:00-17:00; Thu-Sun off.

## Schedule

| ID | WBS | Task | Type | Duration | Start | Finish | Predecessors | Total slack | Constraint |
| --- | --- | --- | --- | --- | --- | --- | --- | --- | --- |
| 1 | 1 | **Editorial Staff Meeting** |  | 60.12d | 2018-05-21 | 2018-08-13 |  | 106.88d |  |
| 2 | 1.1 | Editorial Staff Meeting 1 |  | 1h | 2018-05-21 | 2018-05-21 |  | 166.88d | start no earlier than 2018-05-21 |
| 3 | 1.2 | Editorial Staff Meeting 2 |  | 1h | 2018-06-04 | 2018-06-04 |  | 156.88d | start no earlier than 2018-06-04 |
| 4 | 1.3 | Editorial Staff Meeting 3 |  | 1h | 2018-06-18 | 2018-06-18 |  | 146.88d | start no earlier than 2018-06-18 |
| 5 | 1.4 | Editorial Staff Meeting 4 |  | 1h | 2018-07-02 | 2018-07-02 |  | 136.88d | start no earlier than 2018-07-02 |
| 6 | 1.5 | Editorial Staff Meeting 5 |  | 1h | 2018-07-16 | 2018-07-16 |  | 126.88d | start no earlier than 2018-07-16 |
| 7 | 1.6 | Editorial Staff Meeting 6 |  | 1h | 2018-07-30 | 2018-07-30 |  | 116.88d | start no earlier than 2018-07-30 |
| 8 | 1.7 | Editorial Staff Meeting 7 |  | 1h | 2018-08-13 | 2018-08-13 |  | 106.88d | start no earlier than 2018-08-13 |
| 9 | 2 | **Acquisition** |  | 25d | 2018-05-07 | 2018-06-08 |  | 0d |  |
| 10 | 2.1 | Manuscript received | milestone | 0d | 2018-05-07 | 2018-05-07 |  | 0d |  |
| 11 | 2.2 | Content edit |  | 15d | 2018-05-07 | 2018-05-25 | 10 | 0d |  |
| 12 | 2.3 | Author review of content edit |  | 10d | 2018-05-28 | 2018-06-08 | 11 | 0d |  |
| 13 | 2.4 | Handoff to Editorial | milestone | 0d | 2018-06-08 | 2018-06-08 | 12 | 0d |  |
| 14 | 3 | **Editorial** |  | 35d | 2018-06-11 | 2018-07-27 | 9 | 0d |  |
| 15 | 3.1 | Organize manuscript for copyedit |  | 5d | 2018-06-11 | 2018-06-15 |  | 0d |  |
| 16 | 3.2 | Copyedit |  | 15d | 2018-06-18 | 2018-07-06 | 15 | 0d |  |
| 17 | 3.3 | Author review of copyedit |  | 10d | 2018-07-09 | 2018-07-20 | 16 | 0d |  |
| 18 | 3.4 | Copyedit incorp |  | 5d | 2018-07-23 | 2018-07-27 | 17 | 0d |  |
| 19 | 3.5 | Handoff to Production | milestone | 0d | 2018-07-27 | 2018-07-27 | 18 | 0d |  |
| 20 | 4 | **Design and Production** |  | 70d | 2018-07-30 | 2018-11-02 | 14 | 0d |  |
| 21 | 4.1 | Set pages |  | 15d | 2018-07-30 | 2018-08-17 |  | 0d |  |
| 22 | 4.2 | Interior illustration design |  | 15d | 2018-08-20 | 2018-09-07 | 21 | 0d |  |
| 23 | 4.3 | **1st Pages review** |  | 25d | 2018-09-10 | 2018-10-12 | 22 | 0d |  |
| 24 | 4.3.1 | Proofread and index |  | 10d | 2018-09-10 | 2018-09-21 |  | 0d |  |
| 25 | 4.3.2 | Incorporate 1st Pages review |  | 5d | 2018-09-24 | 2018-09-28 | 24 | 0d |  |
| 26 | 4.3.3 | Send proofed pages to Production | milestone | 0d | 2018-09-28 | 2018-09-28 | 25 | 0d |  |
| 27 | 4.3.4 | Enter page corrections and index |  | 5d | 2018-10-01 | 2018-10-05 | 26 | 0d |  |
| 28 | 4.3.5 | Cover design |  | 5d | 2018-10-08 | 2018-10-12 | 27 | 0d |  |

| ID | WBS | Task | Type | Duration | Start | Finish | Predecessors | Total slack | Calendar |
| --- | --- | --- | --- | --- | --- | --- | --- | --- | --- |
| 29 | 4.4 | **2nd Pages review** |  | 10d | 2018-10-15 | 2018-10-26 |  | 0d |  |
| 30 | 4.4.1 | Proof and review |  | 5d | 2018-10-15 | 2018-10-19 | 28 | 0d |  |
| 31 | 4.4.2 | Send proofed pages to Production | milestone | 0d | 2018-10-19 | 2018-10-19 | 30 | 0d |  |
| 32 | 4.4.3 | Final review |  | 5d | 2018-10-22 | 2018-10-26 | 31 | 0d |  |
| 33 | 4.5 | **Design book's companion website** |  | 5d | 2018-10-29 | 2018-11-02 | 32 | 0d |  |
| 34 | 4.5.1 | Create mockup |  | 3d | 2018-10-29 | 2018-10-31 |  | 0d |  |
| 35 | 4.5.2 | Review with author |  | 2d | 2018-11-01 | 2018-11-02 | 34 | 0d |  |
| 36 | 4.6 | Design and Production complete | milestone | 0d | 2018-11-02 | 2018-11-02 | 35, 32, 28, 22 | 47d |  |
| 37 | 5 | **Color prep and printing** |  | 47d | 2018-11-05 | 2019-01-08 | 33 | 0d |  |
| 38 | 5.1 | Send to printer |  | 1d | 2018-11-05 | 2018-11-05 | 29 | 0d |  |
| 39 | 5.2 | Generate proofs |  | 10d | 2018-11-06 | 2018-11-27 | 38 | 0d | Monday-Wednesday |
| 40 | 5.3 | Print and ship |  | 30d | 2018-11-28 | 2019-01-08 | 39 | 0d |  |
