# Best selling Novel Schedule

Schedule from MS Project, 2018-05-07 to 2018-12-24.

## Calendars

- Standard: Mon-Fri 08:00-12:00, 13:00-17:00; Sat-Sun off.

## Schedule

| ID | WBS | Task | Type | Duration | Start | Finish | Predecessors | Total slack |
| --- | --- | --- | --- | --- | --- | --- | --- | --- |
| 1 | 1 | **Acquisition** |  | 25d | 2018-05-07 | 2018-06-08 |  | 0d |
| 2 | 1.1 | Manuscript received | milestone | 0d | 2018-05-07 | 2018-05-07 |  | 0d |
| 3 | 1.2 | Content edit |  | 15d | 2018-05-07 | 2018-05-25 | 2 | 0d |
| 4 | 1.3 | Author review of content edit |  | 10d | 2018-05-28 | 2018-06-08 | 3 | 0d |
| 5 | 1.4 | Handoff to Editorial | milestone | 0d | 2018-06-08 | 2018-06-08 | 4 | 0d |
| 6 | 2 | **Editorial** |  | 35d | 2018-06-11 | 2018-07-27 | 1 | 0d |
| 7 | 2.1 | Organize manuscript for copyedit |  | 5d | 2018-06-11 | 2018-06-15 |  | 0d |
| 8 | 2.2 | Copyedit |  | 15d | 2018-06-18 | 2018-07-06 | 7 | 0d |
| 9 | 2.3 | Author review of copyedit |  | 10d | 2018-07-09 | 2018-07-20 | 8 | 0d |
| 10 | 2.4 | Copyedit incorp |  | 5d | 2018-07-23 | 2018-07-27 | 9 | 0d |
| 11 | 2.5 | Handoff to Production | milestone | 0d | 2018-07-27 | 2018-07-27 | 10 | 0d |
| 12 | 3 | **Design and Production** |  | 65d | 2018-07-30 | 2018-10-26 | 6 | 0d |
| 13 | 3.1 | Set pages |  | 15d | 2018-07-30 | 2018-08-17 |  | 0d |
| 14 | 3.2 | Interior illustration design |  | 15d | 2018-08-20 | 2018-09-07 | 13 | 0d |
| 15 | 3.3 | **1st Pages review** |  | 25d | 2018-09-10 | 2018-10-12 | 14 | 0d |
| 16 | 3.3.1 | Proofread and index |  | 10d | 2018-09-10 | 2018-09-21 |  | 0d |
| 17 | 3.3.2 | Incorporate 1st Pages review |  | 5d | 2018-09-24 | 2018-09-28 | 16 | 0d |
| 18 | 3.3.3 | Send proofed pages to Production | milestone | 0d | 2018-09-28 | 2018-09-28 | 17 | 0d |
| 19 | 3.3.4 | Enter page corrections and index |  | 5d | 2018-10-01 | 2018-10-05 | 18 | 0d |
| 20 | 3.3.5 | Cover design |  | 5d | 2018-10-08 | 2018-10-12 | 19 | 0d |
| 21 | 3.4 | **2nd Pages review** |  | 10d | 2018-10-15 | 2018-10-26 |  | 0d |
| 22 | 3.4.1 | Proof and review |  | 5d | 2018-10-15 | 2018-10-19 | 20 | 0d |
| 23 | 3.4.2 | Send proofed pages to Production | milestone | 0d | 2018-10-19 | 2018-10-19 | 22 | 0d |
| 24 | 3.4.3 | Final review |  | 5d | 2018-10-22 | 2018-10-26 | 23 | 0d |
| 25 | 3.5 | Design and Production complete | milestone | 0d | 2018-10-26 | 2018-10-26 | 24, 20, 14 | 41d |

| ID | WBS | Task | Duration | Start | Finish | Predecessors | Total slack |
| --- | --- | --- | --- | --- | --- | --- | --- |
| 26 | 4 | **Color prep and printing** | 41d | 2018-10-29 | 2018-12-24 |  | 0d |
| 27 | 4.1 | Send to printer | 1d | 2018-10-29 | 2018-10-29 | 21 | 0d |
| 28 | 4.2 | Generate proofs | 10d | 2018-10-30 | 2018-11-12 | 27 | 0d |
| 29 | 4.3 | Print and ship | 30d | 2018-11-13 | 2018-12-24 | 28 | 0d |
