# CKM Office Renovation

Schedule from MS Project, 2018-05-08 to 2018-05-23, 7 hours a day, costs in $.
Office Renovation Project
Corporate Knowledge Management

## Calendars

- Standard: Mon-Fri 09:00-13:00, 14:00-17:00; Sat-Sun off.

## Resources

| Resource | Group | Unit | Rate | Cost per use |
| --- | --- | --- | --- | --- |
| Carpenter | Contractor |  | 35 |  |
| Carpet Contractor | Contractor |  |  |  |
| Fit-out Consultant | Consultant |  | 65 | 50 |
| IT Consultant | Contractor |  | 80 |  |
| Labourer | Contractor |  | 20 |  |
| Management | Staff |  | 100 |  |
| Painter | Contractor |  | 35 |  |
| Plasterer | Contractor |  | 35 |  |
| Project Manager | Staff |  | 88 |  |
| Staff | Staff |  | 50 |  |
| Telecommunications consultant | Consultant |  | 60 |  |
| Admin Assistant | Staff |  | 45 |  |
| Gyprock | materials | sheet | 60 |  |
| Paint | materials | litre | 30 |  |
| Plaster | materials | bag | 10 |  |
| Carpet | materials | sqm | 100 |  |

## Schedule

| ID | WBS | Task | Type | Duration | Start | Finish | Predecessors | Total slack | Free slack | Resources | Work | Cost |
| --- | --- | --- | --- | --- | --- | --- | --- | --- | --- | --- | --- | --- |
| 1 | 1 | **Restructure Office** |  | 12d | 2018-05-08 | 2018-05-23 |  | 0d |  |  | 64.5h | 19,325 |
| 2 | 1.1 | Erect New Walls |  | 7h | 2018-05-08 | 2018-05-10 |  | 0d |  | Carpenter [200%] | 14h | 490 |
| 3 | 1.2 | Gyprock, Plaster & Finish |  | 14h | 2018-05-10 | 2018-05-14 | 2 | 0d |  | Plasterer; Gyprock [20 sheet]; Plaster [10 bag] | 14h | 11,790 |
| 4 | 1.3 | Install Network Points |  | 5h | 2018-05-15 | 2018-05-15 | 3FS+1ed | 0.5d | 0d | IT Consultant | 5h | 400 |
| 5 | 1.4 | Install Phone Connections |  | 0.5d | 2018-05-15 | 2018-05-15 | 4SS | 0.5d |  | Telecommunications consultant | 3.5h | 700 |
| 6 | 1.5 | Re-Paint |  | 1d | 2018-05-16 | 2018-05-18 | 5 | 0d |  | Painter | 7h | 245 |
| 7 | 1.6 | Carpet |  | 1d | 2018-05-19 | 2018-05-19 | 6FS+1ed | 0d |  | Carpet Contractor | 7h | 5,000 |
| 8 | 1.7 | Install New Furniture |  | 1d | 2018-05-21 | 2018-05-23 | 7 | 0d |  | Labourer | 7h | 140 |
| 9 | 1.8 | Install New PCs |  | 1d | 2018-05-23 | 2018-05-23 | 8 | 0d |  | IT Consultant | 7h | 560 |
| 10 | 1.9 | Refit Office Complete | milestone | 0d | 2018-05-23 | 2018-05-23 | 9 | 0d |  |  |  |  |
