# Scheduling Options

Schedule from MS Project, 2018-05-07 to 2018-06-25, costs in $, A marks actual dates.
Office Renovation Project
Corporate Knowledge Management

## Calendars

- Standard: Mon-Fri 09:00-13:00, 14:00-17:00; Sat-Sun off.

## Resources

| Resource | Group | Unit | Rate | Cost per use |
| --- | --- | --- | --- | --- |
| Carpenter | Contractor |  | 35 |  |
| Carpet | Materials | Lin Metre | 100 |  |
| Carpet Contractor | Contractor |  |  |  |
| Fit-out Consultant | Consultant |  | 65 | 50 |
| Furniture | Asset |  |  |  |
| Gyprock | Material | Sheet | 30 |  |
| Plaster | Material | Bag | 50 |  |
| IT Consultant | Contractor |  | 80 |  |
| Labourer | Contractor |  | 20 |  |
| Management | Staff |  | 100 |  |
| Network Cable & Points | Asset |  |  |  |
| PABX & Points | Asset |  |  |  |
| Paint | Material | Litre | 250 |  |
| Painter | Contractor |  | 35 |  |
| Personal Computers | Asset |  |  |  |
| Phones | Asset |  |  |  |
| Plasterer | Contractor |  | 35 |  |
| Project Manager | Staff |  | 80 |  |
| Staff | Staff |  | 50 |  |
| Telecommunications consultant | Consultant |  | 60 |  |
| Admin Assistant | Staff |  | 45 |  |

## Schedule

| ID | WBS | Task | Type | Duration | Start | Finish | Predecessors | Remaining | Baseline start | Baseline finish | Baseline duration | Total slack | Free slack | Resources | Work | Cost | Baseline cost |
| --- | --- | --- | --- | --- | --- | --- | --- | --- | --- | --- | --- | --- | --- | --- | --- | --- | --- |
| 1 | 1 | **Planning & Research** |  | 7.75d | 2018-05-07 09:00 | 2018-05-17 16:00 |  |  | 2011-04-04 09:00 | 2011-04-14 12:00 | 7.38d | 5.12d |  |  | 27h | 2,376 | 1,920 |
| 2 | 1.1 | Develop Requirements Documentation |  | 1d | 2018-05-07 09:00 | 2018-05-08 10:00 |  |  | 2011-04-04 09:00 | 2011-04-04 17:00 | 0.88d | 5.12d | 0d | Project Manager | 8h | 704 | 560 |
| 3 | 1.2 | Fit-Out Consultant Research |  | 0.5d | 2018-05-08 10:00 | 2018-05-08 15:00 | 2 |  | 2011-04-05 09:00 | 2011-04-05 12:30 | 0.44d | 5.12d | 0d | Project Manager | 4h | 352 | 280 |
| 4 | 1.3 | Telecommunications Consultant Research |  | 0.5d | 2018-05-08 15:00 | 2018-05-09 11:00 | 3 |  | 2011-04-05 12:30 | 2011-04-05 17:00 | 0.44d | 5.12d | 0d | Project Manager | 4h | 352 | 280 |
| 5 | 1.4 | IT Network Contractor Research |  | 0.5d | 2018-05-09 11:00 | 2018-05-09 16:00 | 4 |  | 2011-04-06 09:00 | 2011-04-06 12:30 | 0.44d | 5.12d | 0d | Project Manager | 4h | 352 | 280 |
| 6 | 1.5 | Building Contractors Research |  | 0.5d | 2018-05-09 16:00 | 2018-05-10 12:00 | 5 |  | 2011-04-06 12:30 | 2011-04-06 17:00 | 0.44d | 5.12d | 0d | Project Manager | 4h | 352 | 280 |
| 7 | 1.6 | Submit Requirements to Resources & Request Quotes |  | 2h | 2018-05-10 12:00 | 2018-05-10 15:00 | 6 |  | 2011-04-07 09:00 | 2011-04-07 11:00 | 2h | 5.12d | 0d | Project Manager | 2h | 176 | 160 |
| 8 | 1.7 | Quotes Received |  | 1h | 2018-05-17 15:00 | 2018-05-17 16:00 | 7FS+4.38d |  | 2011-04-14 11:00 | 2011-04-14 12:00 | 1h | 5.12d | 0d | Project Manager | 1h | 88 | 80 |
| 9 | 1.8 | Planning & Research Complete | milestone | 0d | 2018-05-17 16:00 | 2018-05-17 16:00 | 8 |  | 2011-04-14 12:00 | 2011-04-14 12:00 | 0d | 5.12d | 0d |  |  |  |  |
| 10 | 2 | **Management Approval** |  | 2.25d | 2018-05-17 16:00 | 2018-05-22 12:00 |  |  | 2011-04-14 12:00 | 2011-04-15 15:00 | 1.12d | 5.12d |  |  | 19h | 1,684 | 820 |
| 11 | 2.1 | Consolidate Quotes and develop proposal |  | 2d | 2018-05-17 16:00 | 2018-05-22 10:00 | 9 |  | 2011-04-14 12:00 | 2011-04-15 12:00 | 0.88d | 5.12d | 0d | Project Manager | 16h | 1,408 | 560 |
| 12 | 2.2 | Develop Project Plan & Durations |  | 1h | 2018-05-22 10:00 | 2018-05-22 11:00 | 11 |  | 2011-04-15 12:00 | 2011-04-15 13:00 | 1h | 5.12d | 0d | Project Manager | 1h | 88 | 80 |
| 13 | 2.3 | Submit Project Plan & Costs to Management |  | 1h | 2018-05-22 11:00 | 2018-05-22 12:00 | 12 |  | 2011-04-15 14:00 | 2011-04-15 15:00 | 1h | 5.12d | 0d | Project Manager; Management | 2h | 188 | 180 |
| 14 | 2.4 | Management Approval Received | milestone | 0d | 2018-05-22 12:00 | 2018-05-22 12:00 | 13 |  | 2011-04-15 15:00 | 2011-04-15 15:00 | 0d | 5.12d | 0d |  |  |  |  |
| 15 | 3 | **Refit Office** |  | 15.5d | 2018-05-22 12:00 A | 2018-06-15 10:00 |  | 15.5d | 2011-04-15 15:00 | 2011-05-11 17:00 | 13.38d | 5.25d |  |  | 120h | 77,313 | 76,607.5 |
| 16 | 3.1 | Appoint Resources |  | 2h | 2018-05-22 12:00 | 2018-05-22 15:00 | 14 |  | 2011-04-15 15:00 | 2011-04-15 17:00 | 2h | 5.12d | 0d | Project Manager | 2h | 176 | 160 |
| 17 | 3.2 | Staff Briefing |  | 1h | 2018-05-22 15:00 | 2018-05-22 16:00 | 16 |  | 2011-04-18 09:00 | 2011-04-18 10:00 | 1h | 5.12d | 0d | Project Manager; Staff [700%] | 8h | 438 | 430 |
| 18 | 3.3 | **Fit-Out Consultations** |  | 0.88d | 2018-05-22 16:00 | 2018-05-23 16:00 |  |  | 2011-04-18 10:00 | 2011-04-19 09:30 | 0.81d | 5.12d |  |  | 14h | 1,271 | 1,142.5 |
| 19 | 3.3.1 | Office Space / Structure Plan |  | 0.5d | 2018-05-22 16:00 | 2018-05-23 12:00 | 17 |  | 2011-04-18 10:00 | 2011-04-18 14:30 | 0.44d | 5.12d | 0d | Fit-out Consultant; Project Manager | 8h | 662 | 557.5 |
| 20 | 3.3.2 | Select & Order Carpet |  | 1h | 2018-05-23 12:00 | 2018-05-23 13:00 | 19 |  | 2011-04-18 14:30 | 2011-04-18 15:30 | 1h | 5.12d | 0d | Fit-out Consultant; Project Manager | 2h | 203 | 195 |
| 21 | 3.3.3 | Select & Order Paint |  | 1h | 2018-05-23 14:00 | 2018-05-23 15:00 | 20 |  | 2011-04-18 15:30 | 2011-04-18 16:30 | 1h | 5.12d | 0d | Fit-out Consultant; Project Manager | 2h | 203 | 195 |
| 22 | 3.3.4 | Select & Order Office Furniture |  | 1h | 2018-05-23 15:00 | 2018-05-23 16:00 | 21 |  | 2011-04-18 16:30 | 2011-04-19 09:30 | 1h | 5.12d | 0d | Fit-out Consultant; Project Manager | 2h | 203 | 195 |
| 23 | 3.4 | **Telecommuncations Consultations** |  | 0.62d | 2018-05-23 16:00 | 2018-05-24 13:00 |  |  | 2011-04-19 09:30 | 2011-04-19 15:00 | 0.56d | 5.12d |  |  | 9h | 680 | 570 |
| 24 | 3.4.1 | Design Telephone Access Points Map |  | 0.5d | 2018-05-23 16:00 | 2018-05-24 12:00 | 22 |  | 2011-04-19 09:30 | 2011-04-19 13:00 | 0.44d | 5.12d | 0d | Project Manager; Telecommunications consultant | 8h | 592 | 490 |
| 25 | 3.4.2 | Select & Order New PABX |  | 1h | 2018-05-24 12:00 | 2018-05-24 13:00 | 24 |  | 2011-04-19 14:00 | 2011-04-19 15:00 | 1h | 5.12d | 0d | Project Manager | 1h | 88 | 80 |

| ID | WBS | Task | Type | Duration | Start | Finish | Predecessors | Complete | Remaining | Baseline start | Baseline finish | Baseline duration | Total slack | Free slack | Resources | Work | Cost | Baseline cost |
| --- | --- | --- | --- | --- | --- | --- | --- | --- | --- | --- | --- | --- | --- | --- | --- | --- | --- | --- |
| 26 | 3.5 | **IT Networking Consultations** |  | 6.12d | 2018-05-24 14:00 | 2018-06-04 13:00 |  |  |  | 2011-04-19 15:00 | 2011-05-03 12:30 | 5.94d | 5.12d |  |  | 18h | 21,488 | 21,280 |
| 27 | 3.5.1 | Design Network Access Points Map |  | 0.5d | 2018-05-24 14:00 | 2018-05-25 10:00 | 22, 25 |  |  | 2011-04-19 15:00 | 2011-04-20 10:30 | 0.44d | 5.12d | 0d | IT Consultant; Project Manager | 8h | 672 | 560 |
| 28 | 3.5.2 | Select & Order New PCs |  | 1h | 2018-05-25 10:00 | 2018-05-25 11:00 | 27 |  |  | 2011-04-20 10:30 | 2011-04-20 11:30 | 1h | 5.12d | 0d | Project Manager | 1h | 88 | 80 |
| 29 | 3.5.3 | New PCs Arrive |  | 1h | 2018-06-01 11:00 | 2018-06-01 12:00 | 28FS+4.38d |  |  | 2011-04-29 11:30 | 2011-04-29 12:30 | 1h | 5.12d | 0d | Project Manager | 1h | 20,088 | 20,080 |
| 30 | 3.5.4 | Configure SOE on PCs |  | 1d | 2018-06-01 12:00 | 2018-06-04 13:00 | 29 |  |  | 2011-04-29 12:30 | 2011-05-03 12:30 | 0.88d | 5.12d | 0d | IT Consultant | 8h | 640 | 560 |
| 31 | 3.6 | **Restructure Office** |  | 14.12d | 2018-05-24 06:00 A | 2018-06-15 10:00 |  |  | 14.12d | 2011-04-20 06:00 | 2011-05-11 17:00 | 11.38d | 5.25d |  |  | 69h | 53,260 | 53,025 |
| 32 | 3.6.1 | Erect New Walls |  | 7h | 2018-05-24 06:00 | 2018-05-26 08:00 | 22 |  |  | 2011-04-20 06:00 | 2011-04-26 07:00 | 7h | 7d | 0d | Carpenter [200%] | 14h | 490 | 490 |
| 33 | 3.6.2 | Gyprock, Plaster & Finish |  | 14h | 2018-05-26 08:00 | 2018-05-30 08:00 | 32 |  |  | 2011-04-26 07:00 | 2011-04-30 10:00 | 14h | 7d | 2.62d | Plasterer | 14h | 10,490 | 10,490 |
| 34 | 3.6.3 | Install Network Points |  | 5h | 2018-06-04 14:00 | 2018-06-05 11:00 | 33FS+1ed, 30 |  |  | 2011-05-03 12:30 | 2011-05-04 10:30 | 5h | 5.12d | 0d | IT Consultant | 5h | 400 | 400 |
| 35 | 3.6.4 | Install Phone Connections |  | 0.5d | 2018-06-04 14:00 | 2018-06-05 10:00 | 34SS |  |  | 2011-05-03 12:30 | 2011-05-03 17:00 | 0.44d | 5.12d | 0.75d | Telecommunications consultant | 4h | 800 | 700 |
| 36 | 3.6.5 | Re-Paint |  | 1d | 2018-06-06 06:00 | 2018-06-08 08:00 | 35 |  |  | 2011-05-04 06:00 | 2011-05-06 07:00 | 0.88d | 4.38d | 0d | Paint [100 Litre]; Painter | 8h | 25,280 | 25,245 |
| 37 | 3.6.6 | Carpet |  | 1d | 2018-06-09 08:00 | 2018-06-11 08:00 | 36FS+1ed |  |  | 2011-05-07 07:00 | 2011-05-07 15:00 | 0.88d | 4.38d | 0d | Carpet [100 Lin Metre]; Carpet Contractor | 8h | 15,000 | 15,000 |
| 38 | 3.6.7 | Install New Furniture |  | 1d | 2018-06-11 08:00 | 2018-06-14 07:00 | 37 |  |  | 2011-05-09 06:00 | 2011-05-11 07:00 | 0.88d | 5.25d | 0d | Labourer | 8h | 160 | 140 |
| 39 | 3.6.8 | Install New PCs |  | 1d | 2018-06-14 09:00 | 2018-06-15 10:00 | 38 |  |  | 2011-05-11 09:00 | 2011-05-11 17:00 | 0.88d | 5.25d |  | IT Consultant | 8h | 640 | 560 |
| 40 | 3.6.9 | Refit Office Complete | milestone | 0d | 2018-06-15 10:00 A | 2018-06-15 10:00 A | 39 | 100% |  | 2011-05-11 17:00 | 2011-05-11 17:00 | 0d |  |  |  |  |  |  |
| 41 | 4 | **Office Move** |  | 13.75d | 2018-06-01 12:00 | 2018-06-25 10:00 |  |  |  | 2011-04-29 12:30 | 2011-05-16 17:00 | 9.19d | 0d |  |  | 385h | 19,440 | 11,028 |
| 42 | 4.1 | Order packing boxes |  | 1h | 2018-06-01 12:00 | 2018-06-01 13:00 | 29 |  |  | 2011-04-29 12:30 | 2011-04-29 14:30 | 1h | 11.25d | 9.12d | Project Manager | 1h | 88 | 80 |
| 43 | 4.2 | Staff Pack | manual | 0.5d | 2018-06-18 09:00 | 2018-06-18 13:00 | 40, 42 |  |  | 2011-05-12 09:00 | 2011-05-12 12:30 | 0.44d |  |  | Project Manager; Staff [2000%] | 84h | 4,352 | 3,808 |
| 44 | 4.3 | Staff Move | manual | 1.88d | 2018-06-21 09:00 | 2018-06-25 10:00 | 43 |  |  | 2011-05-12 12:30 | 2011-05-14 11:00 | 1.75d |  |  | Staff [2000%] | 300h | 15,000 | 7,140 |
| 45 | 4.4 | Office Move Complete | milestone, manual | 0d | 2018-06-25 09:00 | 2018-06-25 09:00 | 44 |  |  | 2011-05-16 17:00 | 2011-05-16 17:00 | 0d |  |  |  |  |  |  |
