# CKM Office Renovation

Schedule from MS Project, 2025-04-07 to 2025-06-06, 7 hours a day, costs in $, A marks actual dates.
Office Renovation Project
Corporate Knowledge Management

## Calendars

- Standard: Mon-Fri 09:00-13:00, 14:00-17:00; Sat-Sun off. Exceptions (off unless hours are given): 2025-04-18 to 2025-04-21 (Easter), 2025-04-25 (Anzac Day), 2025-05-05 (Labor Day).

## Resources

| Resource | Group | Rate | Cost per use |
| --- | --- | --- | --- |
| Admin Assistant | Staff | 45 |  |
| Carpenter | Contractor | 35 |  |
| Carpet Contractor | Contractor |  |  |
| Fit-out Consultant | Consultant | 65 | 50 |
| Furniture | Asset |  |  |
| IT Consultant | Contractor | 80 |  |
| Labourer | Contractor | 20 |  |
| Management | Staff | 100 |  |
| Network Cable & Points | Asset |  |  |
| PABX & Points | Asset |  |  |
| Painter | Contractor | 35 |  |
| Personal Computers | Asset |  |  |
| Phones | Asset |  |  |
| Plasterer | Contractor | 35 |  |
| Project Manager | Staff | 88 |  |
| Staff | Staff | 50 |  |
| Telecommunications consultant | Consultant | 60 |  |

## Schedule

| ID | WBS | Task | Type | Duration | Start | Finish | Predecessors | Complete | Remaining | Baseline start | Baseline finish | Baseline duration | Total slack | Resources | Work | Actual work | Cost | Baseline cost | Actual cost |
| --- | --- | --- | --- | --- | --- | --- | --- | --- | --- | --- | --- | --- | --- | --- | --- | --- | --- | --- | --- |
| 1 | 1 | **Planning & Research** |  | 12.5d | 2025-04-07 A | 2025-04-28 A |  | 100% |  | 2025-04-07 | 2025-04-28 | 12.5d |  |  | 73.5h | 73.5h | 6,468 | 6,468 | 6,468 |
| 2 | 1.1 | Develop Requirements Documentation |  | 1d | 2025-04-07 A | 2025-04-07 A |  | 100% |  | 2025-04-07 | 2025-04-07 | 1d |  | Project Manager | 7h | 7h | 616 | 616 | 616 |
| 3 | 1.2 | Fit-Out Consultant Research |  | 2d | 2025-04-08 A | 2025-04-09 A | 2 | 100% |  | 2025-04-08 | 2025-04-09 | 2d |  | Project Manager | 14h | 14h | 1,232 | 1,232 | 1,232 |
| 4 | 1.3 | Telecommunications Consultant Research |  | 2d | 2025-04-10 A | 2025-04-11 A | 3 | 100% |  | 2025-04-10 | 2025-04-11 | 2d |  | Project Manager | 14h | 14h | 1,232 | 1,232 | 1,232 |
| 5 | 1.4 | IT Network Contractor Research |  | 2d | 2025-04-14 A | 2025-04-15 A | 4 | 100% |  | 2025-04-14 | 2025-04-15 | 2d |  | Project Manager | 14h | 14h | 1,232 | 1,232 | 1,232 |
| 6 | 1.5 | Building Contractors Research |  | 2d | 2025-04-16 A | 2025-04-17 A | 5 | 100% |  | 2025-04-16 | 2025-04-17 | 2d |  | Project Manager | 14h | 14h | 1,232 | 1,232 | 1,232 |
| 7 | 1.6 | Submit Requirements to Resources & Request Quotes |  | 1d | 2025-04-18 A | 2025-04-18 A | 6 | 100% |  | 2025-04-18 | 2025-04-18 | 1d |  | Project Manager | 7h | 7h | 616 | 616 | 616 |
| 8 | 1.7 | Quotes Received |  | 0.5d | 2025-04-28 A | 2025-04-28 A | 7FS+5d | 100% |  | 2025-04-28 | 2025-04-28 | 0.5d |  | Project Manager | 3.5h | 3.5h | 308 | 308 | 308 |
| 9 | 1.8 | Planning & Research Complete | milestone | 0d | 2025-04-28 A | 2025-04-28 A | 8 | 100% |  | 2025-04-28 | 2025-04-28 | 0d |  |  |  |  |  |  |  |
| 10 | 2 | **Management Approval** |  | 4.14d | 2025-04-28 A | 2025-05-02 A |  | 100% |  | 2025-04-28 | 2025-05-02 | 4.14d |  |  | 29h | 29h | 2,552 | 2,552 | 2,552 |
| 11 | 2.1 | Consolidate Quotes and develop proposal |  | 2d | 2025-04-28 A | 2025-04-30 A | 9 | 100% |  | 2025-04-28 | 2025-04-30 | 2d |  | Project Manager | 14h | 14h | 1,232 | 1,232 | 1,232 |
| 12 | 2.2 | Develop Project Plan & Durations |  | 2d | 2025-04-30 A | 2025-05-02 A | 11 | 100% |  | 2025-04-30 | 2025-05-02 | 2d |  | Project Manager | 14h | 14h | 1,232 | 1,232 | 1,232 |
| 13 | 2.3 | Submit Project Plan & Costs to Management |  | 1h | 2025-05-02 A | 2025-05-02 A | 12 | 100% |  | 2025-05-02 | 2025-05-02 | 1h |  | Project Manager; Management | 1h | 1h | 88 | 88 | 88 |
| 14 | 2.4 | Management Approval Received | milestone | 0d | 2025-05-02 A | 2025-05-02 A | 13 | 100% |  | 2025-05-02 | 2025-05-02 | 0d |  |  |  |  |  |  |  |
| 15 | 3 | **Refit Office** |  | 22.36d | 2025-05-02 A | 2025-06-04 |  | 37% | 14.1d | 2025-05-02 | 2025-06-04 | 22.36d | 2d |  | 128.5h | 43.5h | 7,393.5 | 7,393.5 | 3,586 |
| 16 | 3.1 | Appoint Resources |  | 1d | 2025-05-02 A | 2025-05-05 A | 14 | 100% |  | 2025-05-02 | 2025-05-05 | 1d |  | Project Manager; Admin Assistant | 7h | 7h | 616 | 616 | 616 |
| 17 | 3.2 | Staff Briefing |  | 1h | 2025-05-05 A | 2025-05-05 A | 16 | 100% |  | 2025-05-05 | 2025-05-05 | 1h |  | Staff [500%] | 5h | 5h | 250 | 250 | 250 |
| 18 | 3.3 | **Fit-Out Consultations** |  | 2.29d | 2025-05-05 A | 2025-05-08 A |  | 100% |  | 2025-05-05 | 2025-05-08 | 2.29d |  |  | 17.5h | 17.5h | 1,740 | 1,740 | 1,740 |
| 19 | 3.3.1 | Office Space / Structure Plan |  | 1d | 2025-05-05 A | 2025-05-06 A | 17 | 100% |  | 2025-05-05 | 2025-05-06 | 1d |  | Project Manager; Fit-out Consultant | 7h | 7h | 666 | 666 | 666 |
| 20 | 3.3.2 | Select & Order Carpet |  | 0.5d | 2025-05-06 A | 2025-05-07 A | 19 | 100% |  | 2025-05-06 | 2025-05-07 | 0.5d |  | Project Manager; Fit-out Consultant | 3.5h | 3.5h | 358 | 358 | 358 |
| 21 | 3.3.3 | Select & Order Paint |  | 0.5d | 2025-05-07 A | 2025-05-07 A | 20 | 100% |  | 2025-05-07 | 2025-05-07 | 0.5d |  | Project Manager; Fit-out Consultant | 3.5h | 3.5h | 358 | 358 | 358 |
| 22 | 3.3.4 | Select & Order Office Furniture |  | 0.5d | 2025-05-07 A | 2025-05-08 A | 21 | 100% |  | 2025-05-07 | 2025-05-08 | 0.5d |  | Project Manager; Fit-out Consultant | 3.5h | 3.5h | 358 | 358 | 358 |
| 23 | 3.4 | **Telecommuncations Consultations** |  | 1.5d | 2025-05-08 A | 2025-05-09 |  | 67% | 0.5d | 2025-05-08 | 2025-05-09 | 1.5d | 20.21d |  | 14h | 7h | 787.5 | 787.5 | 420 |
| 24 | 3.4.1 | Design Telephone Access Points Map |  | 1d | 2025-05-08 A | 2025-05-09 A | 22 | 100% |  | 2025-05-08 | 2025-05-09 | 1d |  | Telecommunications consultant | 7h | 7h | 420 | 420 | 420 |
| 25 | 3.4.2 | Select & Order New PABX |  | 0.5d | 2025-05-09 | 2025-05-09 | 24 |  |  | 2025-05-09 | 2025-05-09 | 0.5d | 20.21d | Telecommunications consultant; Admin Assistant | 7h |  | 367.5 | 367.5 |  |

| ID | WBS | Task | Type | Duration | Start | Finish | Predecessors | Complete | Remaining | Baseline start | Baseline finish | Baseline duration | Total slack | Free slack | Resources | Work | Actual work | Cost | Baseline cost | Actual cost |
| --- | --- | --- | --- | --- | --- | --- | --- | --- | --- | --- | --- | --- | --- | --- | --- | --- | --- | --- | --- | --- |
| 26 | 3.5 | **IT Networking Consultations** |  | 8.14d | 2025-05-08 A | 2025-05-20 |  | 32% | 5.55d | 2025-05-08 | 2025-05-20 | 8.14d | 1.57d |  |  | 22h | 7h | 1,760 | 1,760 | 560 |
| 27 | 3.5.1 | Design Network Access Points Map |  | 1d | 2025-05-08 A | 2025-05-09 A | 22 | 100% |  | 2025-05-08 | 2025-05-09 | 1d |  |  | IT Consultant | 7h | 7h | 560 | 560 | 560 |
| 28 | 3.5.2 | Select & Order New PCs |  | 1d | 2025-05-09 | 2025-05-12 | 27 |  |  | 2025-05-09 | 2025-05-12 | 1d | 1.57d | 0d | IT Consultant | 7h |  | 560 | 560 |  |
| 29 | 3.5.3 | New PCs Arrive |  | 1h | 2025-05-19 | 2025-05-19 | 28FS+5d |  |  | 2025-05-19 | 2025-05-19 | 1h | 1.57d | 0d | IT Consultant | 1h |  | 80 | 80 |  |
| 30 | 3.5.4 | Configure SOE on PCs |  | 1d | 2025-05-19 | 2025-05-20 | 29 |  |  | 2025-05-19 | 2025-05-20 | 1d | 1.57d | 0.57d | IT Consultant | 7h |  | 560 | 560 |  |
| 31 | 3.6 | **Restructure Office** |  | 11d | 2025-05-21 | 2025-06-04 |  |  |  | 2025-05-21 | 2025-06-04 | 11d | 0d |  |  | 63h |  | 2,240 | 2,240 |  |
| 32 | 3.6.1 | Erect New Walls |  | 7h | 2025-05-21 | 2025-05-23 | 30 |  |  | 2025-05-21 | 2025-05-23 | 7h | 1d | 0d | Labourer; Carpenter [200%] | 21h |  | 630 | 630 |  |
| 33 | 3.6.2 | Gyprock, Plaster & Finish |  | 7h | 2025-05-23 | 2025-05-24 | 32 |  |  | 2025-05-23 | 2025-05-24 | 7h | 0d |  | Plasterer | 7h |  | 245 | 245 |  |
| 34 | 3.6.3 | Install Network Points |  | 5h | 2025-05-27 | 2025-05-27 | 33FS+1d |  |  | 2025-05-27 | 2025-05-27 | 5h | 0.71d | 0d | Telecommunications consultant | 5h |  | 300 | 300 |  |
| 35 | 3.6.4 | Install Phone Connections |  | 2h | 2025-05-27 | 2025-05-27 | 34SS |  |  | 2025-05-27 | 2025-05-27 | 2h | 0.71d |  | Telecommunications consultant | 2h |  | 120 | 120 |  |
| 36 | 3.6.5 | Re-Paint |  | 1d | 2025-05-28 | 2025-05-30 | 35 |  |  | 2025-05-28 | 2025-05-30 | 1d | 0d |  | Painter | 7h |  | 245 | 245 |  |
| 37 | 3.6.6 | Carpet |  | 1d | 2025-05-31 | 2025-05-31 | 36FS+1d |  |  | 2025-05-31 | 2025-05-31 | 1d | 0d |  | Carpet Contractor | 7h |  |  |  |  |
| 38 | 3.6.7 | Install New Furniture |  | 1d | 2025-06-02 | 2025-06-04 | 37 |  |  | 2025-06-02 | 2025-06-04 | 1d | 0d |  | Labourer | 7h |  | 140 | 140 |  |
| 39 | 3.6.8 | Install New PCs |  | 1d | 2025-06-04 | 2025-06-04 | 38 |  |  | 2025-06-04 | 2025-06-04 | 1d | 0d |  | IT Consultant | 7h |  | 560 | 560 |  |
| 40 | 3.6.9 | Refit Office Complete | milestone | 0d | 2025-06-04 | 2025-06-04 | 39 |  |  | 2025-06-04 | 2025-06-04 | 0d | 0d |  |  |  |  |  |  |  |
| 41 | 4 | **Office Move** |  | 3d | 2025-06-04 | 2025-06-06 |  |  |  | 2025-06-04 | 2025-06-06 | 3d | 0d |  |  | 141h |  | 7,045 | 7,045 |  |
| 42 | 4.1 | Order packing boxes |  | 1h | 2025-06-04 | 2025-06-04 | 38 |  |  | 2025-06-04 | 2025-06-04 | 1h | 2.86d |  | Admin Assistant | 1h |  | 45 | 45 |  |
| 43 | 4.2 | Staff Pack |  | 1d | 2025-06-05 | 2025-06-05 | 40 |  |  | 2025-06-05 | 2025-06-05 | 1d | 0d |  | Staff [1000%] | 70h |  | 3,500 | 3,500 |  |
| 44 | 4.3 | Staff Move |  | 1d | 2025-06-06 | 2025-06-06 | 43 |  |  | 2025-06-06 | 2025-06-06 | 1d | 0d |  | Staff [1000%] | 70h |  | 3,500 | 3,500 |  |
| 45 | 4.4 | Office Move Complete | milestone | 0d | 2025-06-06 | 2025-06-06 | 44 |  |  | 2025-06-06 | 2025-06-06 | 0d | 0d |  |  |  |  |  |  |  |
