# House

Schedule from MS Project, 2025-04-07 to 2025-07-07, costs in $.
Templates

## Calendars

- Standard: Mon-Fri 08:00-12:00, 13:00-17:00; Sat-Sun off.

## Resources

| Resource | Rate |
| --- | --- |
| Architect | 250 |
| Drafter | 125 |
| Accountant | 175 |
| Admin Assistant | 100 |
| Supervisor | 150 |
| Labourer | 80 |
| Equipment Operators | 85 |
| Drivers | 85 |
| Carpenter | 125 |
| Trade Assistants | 75 |
| Electrical Subcontractor | 200 |
| Plumbing Subcontractor | 200 |
| Roofing Subcontractor | 200 |
| Building Inspector | 1000 |
| Concreting Subcontractor | 240 |
| Grader | 160 |
| Truck | 125 |
| Digger | 170 |
| Owner |  |
| Cabinetmaker | 250 |
| Bricklaying Subcontractor | 225 |
| Plastering Contractor | 225 |
| Painting Contractor | 230 |
| Carpet Contractor | 280 |

## Schedule

| ID | WBS | Task | Type | Duration | Start | Finish | Predecessors | Total slack | Free slack | Resources | Work | Cost |
| --- | --- | --- | --- | --- | --- | --- | --- | --- | --- | --- | --- | --- |
| 1 | 1 | **Design & Approvals** |  | 11d | 2025-04-07 | 2025-04-21 |  | 1d |  |  | 96h | 20,800 |
| 2 | 1.1 | Architectural Plans |  | 2w | 2025-04-07 | 2025-04-18 |  | 1d | 0d | Architect | 80h | 20,000 |
| 3 | 1.2 | Council approval |  | 1d | 2025-04-21 | 2025-04-21 | 2 | 1d | 0d | Admin Assistant; Owner | 16h | 800 |
| 4 | 2 | **Site Clearing and Setup** |  | 7d | 2025-05-12 | 2025-05-20 |  | 1d |  |  | 384h | 37,640 |
| 5 | 2.1 | Site preparation |  | 3d | 2025-05-12 | 2025-05-14 | 3FS+14d | 1d | 0d | Grader; Drivers; Labourer | 72h | 7,800 |
| 6 | 2.2 | Delivery of Materials |  | 1d | 2025-05-12 | 2025-05-12 | 5SS | 40d |  | Truck [200%]; Drivers [200%] | 32h | 3,360 |
| 7 | 2.3 | Lay Foundations |  | 2d | 2025-05-15 | 2025-05-16 | 5 | 1d | 0d | Labourer [400%]; Concreting Subcontractor; Trade Assistants [800%] | 208h | 18,560 |
| 8 | 2.4 | External Plumbing |  | 1d | 2025-05-19 | 2025-05-19 | 7 | 1d | 0d | Plumbing Subcontractor; Labourer; Trade Assistants | 24h | 2,840 |
| 9 | 2.5 | Pour foundation slab |  | 1d | 2025-05-20 | 2025-05-20 | 8 | 1d | 0d | Labourer [400%]; Concreting Subcontractor; Trade Assistants | 48h | 5,080 |
| 10 | 3 | **Framing and Externals** |  | 12d | 2025-05-21 | 2025-06-05 |  | 0d |  |  | 592h | 59,080 |
| 11 | 3.1 | Erect house frame |  | 3d | 2025-05-21 | 2025-05-23 | 9 | 1d | 0d | Carpenter [400%]; Labourer [200%]; Trade Assistants [400%] | 240h | 23,040 |
| 12 | 3.2 | Roofing tiles |  | 4.12d | 2025-05-26 | 2025-05-29 | 11 | 0d |  | Roofing Subcontractor; Labourer [200%] | 72h | 8,640 |
| 13 | 3.3 | Erect Brick Walls |  | 5d | 2025-05-30 | 2025-06-05 | 12 | 0d |  | Bricklaying Subcontractor; Labourer [200%]; Trade Assistants [400%] | 280h | 27,400 |
| 14 | 4 | **Internal Fitout** |  | 22d | 2025-06-06 | 2025-07-07 |  | 0d |  |  | 520h | 68,520 |
| 15 | 4.1 | Fit Windows & Doors |  | 2d | 2025-06-06 | 2025-06-09 | 13 | 0d |  | Carpenter [200%]; Trade Assistants [200%] | 64h | 6,400 |
| 16 | 4.2 | Electrical Cables |  | 1d | 2025-06-10 | 2025-06-10 | 15 | 0d |  | Electrical Subcontractor | 8h | 1,600 |
| 17 | 4.3 | Internal Plumbing |  | 1d | 2025-06-10 | 2025-06-10 | 16SS | 0d |  | Plumbing Subcontractor; Trade Assistants [200%] | 24h | 2,800 |
| 18 | 4.4 | Plaster Walls |  | 5d | 2025-06-11 | 2025-06-17 | 17 | 0d |  | Plastering Contractor | 40h | 9,000 |
| 19 | 4.5 | Internal Doors and Trim |  | 4d | 2025-06-18 | 2025-06-23 | 18 | 0d |  | Carpenter [200%]; Trade Assistants [400%] | 192h | 17,600 |
| 20 | 4.6 | Install Kitchen |  | 2d | 2025-06-24 | 2025-06-25 | 19 | 0d |  | Cabinetmaker; Trade Assistants [200%] | 48h | 6,400 |
| 21 | 4.7 | Install Bathroom |  | 2d | 2025-06-24 | 2025-06-25 | 20SS | 0d |  | Plumbing Subcontractor; Trade Assistants [200%]; Labourer | 64h | 6,880 |
| 22 | 4.8 | Final Electrical Fittings |  | 2d | 2025-06-26 | 2025-06-27 | 21 | 0d |  | Electrical Subcontractor | 16h | 3,200 |
| 23 | 4.9 | Final Plumbing Fittings |  | 2d | 2025-06-26 | 2025-06-27 | 22SS | 0d |  | Plumbing Subcontractor | 16h | 3,200 |
| 24 | 4.10 | Paint |  | 5d | 2025-06-30 | 2025-07-04 | 23 | 0d |  | Painting Contractor | 40h | 9,200 |
| 25 | 4.11 | Carpet laying |  | 1d | 2025-07-07 | 2025-07-07 | 24 | 0d |  | Carpet Contractor | 8h | 2,240 |
| 26 | 4.12 | Practical Completion | milestone | 0d | 2025-07-07 | 2025-07-07 | 25 | 0d |  |  |  |  |
