# Lab Exercise 3

Schedule from MS Project, 2025-04-07 to 2025-10-03, 7.5 hours a day, costs in $.
Odyssey Training

## Calendars

- Standard: Mon-Fri 08:00-12:00, 12:30-16:00; Sat-Sun off. Exceptions (off unless hours are given): 2025-04-18 to 2025-04-21 (Easter), 2025-04-25 (Anzac day), 2025-05-05 (Labor Day).

## Resources

| Resource | Rate | Cost per use |
| --- | --- | --- |
| Appliance contractor | 40 |  |
| Architect | 75 |  |
| Carpenter | 30 |  |
| Cleaner | 30 |  |
| Concrete contractor | 60 |  |
| Electrician | 50 |  |
| Fencing contractor | 40 |  |
| Flooring contractor | 45 |  |
| General contractor | 35 |  |
| Heating and AC contractor | 50 |  |
| Inspector | 80 | 300 |
| Insulation contractor | 45 |  |
| Landscape contractor | 55 |  |
| Owner |  |  |
| Painting contractor | 55 |  |
| Plasterer | 50 |  |
| Plumbing contractor | 50 |  |
| Roofing contractor | 40 |  |
| Site excavation contractor | 60 |  |
| Contract Electrician | 80 |  |

## Schedule

| ID | WBS | Task | Type | Duration | Start | Finish | Predecessors | Total slack | Resources | Work | Cost |
| --- | --- | --- | --- | --- | --- | --- | --- | --- | --- | --- | --- |
| 1 | 1 | **General Conditions** |  | 36d | 2025-04-07 | 2025-05-30 |  | 0d |  | 382.5h | 16,875 |
| 2 | 1.1 | Finalize plans and develop estimate with owner, architect |  | 20d | 2025-04-07 | 2025-05-08 |  | 0d | Owner; Architect | 300h | 11,250 |
| 3 | 1.2 | Sign contract and notice to proceed |  | 1d | 2025-05-16 | 2025-05-16 | 2FS+5d | 0d | Owner | 7.5h |  |
| 4 | 1.3 | Apply for Permits |  | 10d | 2025-05-19 | 2025-05-30 | 3 | 0d | Architect | 75h | 5,625 |
| 5 | 1.4 | General Conditions Complete | milestone | 0d | 2025-05-30 | 2025-05-30 | 4 | 0d |  |  |  |
| 6 | 2 | **Site Work** |  | 3d | 2025-06-02 | 2025-06-04 |  | 0d |  | 22.5h | 1,200 |
| 7 | 2.1 | Clear and grub lot |  | 1d | 2025-06-02 | 2025-06-02 | 5 | 0d | Site excavation contractor | 7.5h | 450 |
| 8 | 2.2 | Install temporary power service |  | 1d | 2025-06-03 | 2025-06-03 | 7 | 0d | Electrician | 7.5h | 375 |
| 9 | 2.3 | Install underground utilities |  | 1d | 2025-06-04 | 2025-06-04 | 8 | 0d | Electrician | 7.5h | 375 |
| 10 | 2.4 | Site Work Complete | milestone | 0d | 2025-06-04 | 2025-06-04 | 9 | 0d |  |  |  |
| 11 | 3 | **Foundation** |  | 14d | 2025-06-05 | 2025-06-24 |  | 0d |  | 67.5h | 4,500 |
| 12 | 3.1 | Excavate for foundations |  | 3d | 2025-06-05 | 2025-06-09 | 10 | 0d | Site excavation contractor | 22.5h | 1,350 |
| 13 | 3.2 | Place concrete for foundations |  | 3d | 2025-06-10 | 2025-06-12 | 12 | 0d | Concrete contractor | 22.5h | 1,350 |
| 14 | 3.3 | Cure foundations for 7 days |  | 7ed | 2025-06-12 | 2025-06-19 | 13 | 2.13d |  |  |  |
| 15 | 3.4 | Perform foundation inspection |  | 1d | 2025-06-20 | 2025-06-20 | 14 | 0d | Inspector | 7.5h | 900 |
| 16 | 3.5 | Backfill foundation |  | 2d | 2025-06-23 | 2025-06-24 | 15 | 0d | Site excavation contractor | 15h | 900 |
| 17 | 3.6 | Foundations Complete | milestone | 0d | 2025-06-24 | 2025-06-24 | 16 | 0d |  |  |  |
| 18 | 4 | **Framing** |  | 13d | 2025-06-25 | 2025-07-11 |  | 0d |  | 300h | 9,900 |
| 19 | 4.1 | Install joists |  | 2d | 2025-06-25 | 2025-06-26 | 17 | 0d | Carpenter [300%] | 45h | 1,350 |
| 20 | 4.2 | Lay decking |  | 2d | 2025-06-27 | 2025-06-30 | 19 | 0d | Carpenter [300%] | 45h | 1,350 |
| 21 | 4.3 | Frame walls |  | 4d | 2025-07-01 | 2025-07-04 | 20 | 0d | Carpenter [300%] | 90h | 2,700 |
| 22 | 4.4 | Frame corners |  | 1d | 2025-07-07 | 2025-07-07 | 21 | 0d | Carpenter [300%] | 22.5h | 675 |
| 23 | 4.5 | Complete roof framing |  | 3d | 2025-07-08 | 2025-07-10 | 22 | 0d | Carpenter [300%]; Roofing contractor | 90h | 2,925 |
| 24 | 4.6 | Conduct framing inspection |  | 1d | 2025-07-11 | 2025-07-11 | 23 | 0d | Inspector | 7.5h | 900 |
| 25 | 4.7 | Framing Complete | milestone | 0d | 2025-07-11 | 2025-07-11 | 24 | 0d |  |  |  |

| ID | WBS | Task | Type | Duration | Start | Finish | Predecessors | Total slack | Free slack | Resources | Work | Cost |
| --- | --- | --- | --- | --- | --- | --- | --- | --- | --- | --- | --- | --- |
| 26 | 5 | **Exterior Finishes** |  | 19d | 2025-07-14 | 2025-08-07 |  | 0d |  |  | 427.5h | 14,962.5 |
| 27 | 5.1 | Complete exterior brick |  | 16d | 2025-07-14 | 2025-08-04 | 25 | 0d |  | General contractor [300%] | 360h | 12,600 |
| 28 | 5.2 | Complete exterior siding |  | 3d | 2025-08-05 | 2025-08-07 | 27 | 0d |  | General contractor [300%] | 67.5h | 2,362.5 |
| 29 | 5.3 | Exterior Finishes Complete | milestone | 0d | 2025-08-07 | 2025-08-07 | 28 | 0d |  |  |  |  |
| 30 | 6 | **Utility Rough-Ins** |  | 7d | 2025-08-08 | 2025-08-18 |  | 0d |  |  | 135h | 8,775 |
| 31 | 6.1 | Rough-in plumbing |  | 5d | 2025-08-08 | 2025-08-14 | 29 | 0d |  | Plumbing contractor | 37.5h | 1,875 |
| 32 | 6.2 | Conduct rough-in plumbing inspection |  | 1d | 2025-08-15 | 2025-08-15 | 31 | 0d |  | Inspector | 7.5h | 900 |
| 33 | 6.3 | Rough-in electrical |  | 5d | 2025-08-08 | 2025-08-14 | 29 | 1d |  | Electrician | 37.5h | 1,875 |
| 34 | 6.4 | Conduct rough-in electrical inspection |  | 1d | 2025-08-18 | 2025-08-18 | 33, 32 | 0d |  | Inspector | 7.5h | 900 |
| 35 | 6.5 | Rough-in AC |  | 3d | 2025-08-08 | 2025-08-12 | 29 | 3d | 0d | Heating and AC contractor | 22.5h | 1,125 |
| 36 | 6.6 | Conduct rough-in AC inspection |  | 1d | 2025-08-13 | 2025-08-13 | 35 | 3d |  | Inspector | 7.5h | 900 |
| 37 | 6.7 | Rough-in communication - phone, cable, computer, alarm |  | 2d | 2025-08-08 | 2025-08-11 | 29 | 5d |  | Contract Electrician | 15h | 1,200 |
| 38 | 6.8 | Utility Rough-Ins Complete | milestone | 0d | 2025-08-18 | 2025-08-18 | 32, 34, 36, 37 | 0d |  |  |  |  |
| 39 | 7 | **Interior Finishes** |  | 34d | 2025-08-19 | 2025-10-03 |  | 0d |  |  | 300h | 16,462.5 |
| 40 | 7.1 | **Insulation** |  | 3d | 2025-08-19 | 2025-08-21 |  | 0d |  |  | 22.5h | 1,575 |
| 41 | 7.1.1 | Place wall insulation |  | 1d | 2025-08-19 | 2025-08-19 | 38 | 0d |  | Insulation contractor | 7.5h | 337.5 |
| 42 | 7.1.2 | Place ceiling insulation |  | 1d | 2025-08-20 | 2025-08-20 | 41 | 0d |  | Insulation contractor | 7.5h | 337.5 |
| 43 | 7.1.3 | Conduct insulation inspection |  | 1d | 2025-08-21 | 2025-08-21 | 42 | 0d |  | Inspector | 7.5h | 900 |
| 44 | 7.2 | **Gyprock** |  | 5d | 2025-08-22 | 2025-08-28 |  | 0d |  |  | 37.5h | 1,875 |
| 45 | 7.2.1 | Install gyprock - walls |  | 2d | 2025-08-22 | 2025-08-25 | 43 | 0d |  | Plasterer | 15h | 750 |
| 46 | 7.2.2 | Install gyprock - overhead |  | 2d | 2025-08-26 | 2025-08-27 | 45 | 0d |  | Plasterer | 15h | 750 |
| 47 | 7.2.3 | Tape and float gyprock |  | 1d | 2025-08-28 | 2025-08-28 | 46 | 0d |  | Plasterer | 7.5h | 375 |
| 48 | 7.3 | **Paint** |  | 5d | 2025-08-29 | 2025-09-04 |  | 0d |  |  | 75h | 4,125 |
| 49 | 7.3.1 | Undercoat all interior |  | 1d | 2025-08-29 | 2025-08-29 | 47 | 0d |  | Painting contractor [200%] | 15h | 825 |
| 50 | 7.3.2 | Paint all interior |  | 2d | 2025-09-01 | 2025-09-02 | 49 | 0d |  | Painting contractor [200%] | 30h | 1,650 |
| 51 | 7.3.3 | Paint exterior siding & trim work |  | 2d | 2025-09-03 | 2025-09-04 | 50 | 0d |  | Painting contractor [200%] | 30h | 1,650 |

| ID | WBS | Task | Type | Duration | Start | Finish | Predecessors | Total slack | Constraint | Resources | Work | Cost |
| --- | --- | --- | --- | --- | --- | --- | --- | --- | --- | --- | --- | --- |
| 52 | 7.4 | **Cabinets** |  | 4d | 2025-09-05 | 2025-09-10 |  | 0d |  |  | 30h | 1,050 |
| 53 | 7.4.1 | Install kitchen cabinets |  | 2d | 2025-09-05 | 2025-09-08 | 51 | 0d |  | General contractor | 15h | 525 |
| 54 | 7.4.2 | Install bath and cabinets |  | 2d | 2025-09-09 | 2025-09-10 | 53 | 0d |  | General contractor | 15h | 525 |
| 55 | 7.5 | **Finish Plumbing** |  | 6d | 2025-09-11 | 2025-09-18 |  | 0d |  |  | 45h | 2,775 |
| 56 | 7.5.1 | Complete kitchen plumbing |  | 1d | 2025-09-11 | 2025-09-11 | 54 | 0d |  | Plumbing contractor | 7.5h | 375 |
| 57 | 7.5.2 | Complete bath and plumbing |  | 4d | 2025-09-12 | 2025-09-17 | 56 | 0d |  | Plumbing contractor | 30h | 1,500 |
| 58 | 7.5.3 | Conduct finish plumbing inspection |  | 1d | 2025-09-18 | 2025-09-18 | 57 | 0d |  | Inspector | 7.5h | 900 |
| 59 | 7.6 | **Finish Electrical** |  | 4d | 2025-09-19 | 2025-09-24 |  | 0d |  |  | 30h | 2,025 |
| 60 | 7.6.1 | Complete circuits to service panel |  | 1d | 2025-09-19 | 2025-09-19 | 58 | 0d |  | Electrician | 7.5h | 375 |
| 61 | 7.6.2 | Conduct finish electrical inspection |  | 1d | 2025-09-22 | 2025-09-22 | 60 | 0d |  | Inspector | 7.5h | 900 |
| 62 | 7.6.3 | Complete communications wiring - phone, cable, computer, alarm |  | 2d | 2025-09-23 | 2025-09-24 | 61 | 0d |  | Electrician | 15h | 750 |
| 63 | 7.7 | **Finish AC** |  | 2d | 2025-09-25 | 2025-09-26 |  | 0d |  |  | 15h | 1,275 |
| 64 | 7.7.1 | Complete AC |  | 1d | 2025-09-25 | 2025-09-25 | 62 | 0d |  | Heating and AC contractor | 7.5h | 375 |
| 65 | 7.7.2 | Conduct AC inspection |  | 1d | 2025-09-26 | 2025-09-26 | 64 | 0d |  | Inspector | 7.5h | 900 |
| 66 | 7.8 | **Carpet, Tile and Appliances** |  | 5d | 2025-09-29 | 2025-10-03 |  | 0d |  |  | 45h | 1,762.5 |
| 67 | 7.8.1 | Tile entry, kitchen and baths |  | 3d | 2025-09-29 | 2025-10-01 | 65 | 0d |  | General contractor | 22.5h | 787.5 |
| 68 | 7.8.2 | Carpet |  | 2d | 2025-10-01 | 2025-10-02 | 67FS-1d | 0d |  | Flooring contractor | 15h | 675 |
| 69 | 7.8.3 | Install appliances |  | 1d | 2025-10-03 | 2025-10-03 | 68 | 0d |  | Appliance contractor | 7.5h | 300 |
| 70 | 7.9 | Interior Finishes Complete | milestone | 0d | 2025-10-03 | 2025-10-03 | 69 | 0d |  |  |  |  |
| 71 | 8 | **Landscaping and Grounds Work** |  | 6d | 2025-09-26 | 2025-10-03 |  | 0d |  |  | 52.5h | 2,737.5 |
| 72 | 8.1 | Pour concrete driveway |  | 2d | 2025-09-26 | 2025-09-29 | 29 | 0d | as late as possible | Concrete contractor | 15h | 900 |
| 73 | 8.2 | Install fence |  | 2d | 2025-09-30 | 2025-10-01 | 72 | 0d |  | Fencing contractor | 15h | 600 |
| 74 | 8.3 | Landscaping |  | 3d | 2025-10-01 | 2025-10-03 | 73FS-5% | 0d |  | Landscape contractor | 22.5h | 1,237.5 |
| 75 | 8.4 | Landscaping and Grounds Work Complete | milestone | 0d | 2025-10-03 | 2025-10-03 | 74 | 0d |  |  |  |  |
