# Diving Pool Construction Project

Schedule from MS Project, 2025-04-07 to 2025-07-24, costs in $.
Odyssey Training

## Calendars

- Standard: Mon-Fri 08:00-12:30, 13:30-17:00; Sat-Sun off. Exceptions (off unless hours are given): 2025-04-18 to 2025-04-21 (Easter), 2025-04-25 (Anzac Day), 2025-05-05 (Labor Day).

## Resources

| Resource | Group | Rate |
| --- | --- | --- |
| Designer | Internal | 200 |
| Drafter | Internal | 150 |
| Accountant | Internal | 150 |
| Admin Assistant | Internal | 95 |
| Supervisor | Internal | 100 |
| Labourer | Internal | 80 |
| Equipment Operators | Internal | 80 |
| Drivers | Internal | 40 |
| Riggers | Internal | 100 |
| Welders | Internal | 100 |
| Boilermakers | Internal | 100 |
| Trade Assistants | Internal | 70 |
| Electrician | Internal | 150 |
| Plumbers | External hire | 100 |
| Testers | Subcontractor | 150 |
| Building Inspector | External | 300 |
| Concreting Subcontractor | Subcontractor |  |
| Crane Hire Subcontractor | Subcontractor |  |
| Bulldozer | Equipment | 187.5 |
| Semitrailer | Equipment | 312.5 |
| Digger | Equipment | 187.5 |

## Schedule

| ID | WBS | Task | Type | Duration | Start | Finish | Predecessors | Total slack | Free slack | Resources | Work | Cost |
| --- | --- | --- | --- | --- | --- | --- | --- | --- | --- | --- | --- | --- |
| 1 | 1 | **Planning** |  | 21d | 2025-04-07 | 2025-05-09 |  | 0d |  |  | 270.6h | 45,190 |
| 2 | 1.1 | Design Plans |  | 2w | 2025-04-07 | 2025-04-22 |  | 0d |  | Designer; Drafter [200%] | 240h | 40,000 |
| 3 | 1.2 | Cost Estimation |  | 1d | 2025-04-23 | 2025-04-23 | 2 | 0d |  | Designer; Drafter [50%]; Accountant [20%] | 13.6h | 2,440 |
| 4 | 1.3 | Apply for loans |  | 2w | 2025-04-24 | 2025-05-09 | 3 | 52d | 0d | Accountant [75%] | 10h | 1,500 |
| 5 | 1.4 | Apply for permits |  | 2w | 2025-04-24 | 2025-05-09 | 3 | 0d |  | Drafter [37.5%]; Designer [50%] | 7h | 1,250 |
| 6 | 1.5 | Planning complete | milestone | 0d | 2025-05-09 | 2025-05-09 | 5 | 54d |  |  |  |  |
| 7 | 2 | **Site Preparation** |  | 7d | 2025-05-12 | 2025-05-20 |  | 0d |  |  | 440h | 52,260 |
| 8 | 2.1 | Order materials |  | 2d | 2025-05-12 | 2025-05-13 | 5, 4 | 52d |  | Drafter; Admin Assistant | 32h | 3,920 |
| 9 | 2.2 | Site preparation |  | 1w | 2025-05-12 | 2025-05-16 | 5 | 0d |  | Labourer [400%]; Supervisor; Equipment Operators; Bulldozer | 280h | 27,500 |
| 10 | 2.3 | Delivery of materials to site |  | 2d | 2025-05-19 | 2025-05-20 | 9 | 47d | 0d | Drafter; Admin Assistant; Drivers [300%]; Semitrailer [300%] | 128h | 20,840 |
| 11 | 2.4 | Site Prep finalised | milestone | 0d | 2025-05-20 | 2025-05-20 | 10 | 47d |  |  |  |  |
| 12 | 3 | **Foundation** |  | 9.75d | 2025-05-19 | 2025-05-30 |  | 0d |  |  | 504h | 48,600 |
| 13 | 3.1 | Dig footings |  | 1w | 2025-05-19 | 2025-05-23 | 9 | 0d |  | Supervisor; Labourer [400%]; Equipment Operators; Digger | 280h | 27,500 |
| 14 | 3.2 | Pour concrete |  | 3d | 2025-05-22 | 2025-05-27 | 13FS-2.5% | 0d |  | Concreting Subcontractor | 24h |  |
| 15 | 3.3 | Dig drainage trenches |  | 1w | 2025-05-23 | 2025-05-30 | 14FS-2d | 37.25d | 0d | Supervisor; Labourer [200%]; Equipment Operators; Bulldozer | 200h | 21,100 |
| 16 | 3.4 | Foundations completed | milestone | 0d | 2025-05-30 | 2025-05-30 | 14, 15 | 39.25d |  |  |  |  |
| 17 | 4 | **Building & Construction** |  | 39d | 2025-05-29 | 2025-07-23 |  | 0d |  |  | 3384h | 324,400 |
| 18 | 4.1 | Pour Concrete in trenches |  | 2d | 2025-05-30 | 2025-06-03 | 15 | 37.25d | 36d | Concreting Subcontractor | 16h |  |
| 19 | 4.2 | Pile Driving |  | 3w | 2025-05-29 | 2025-06-19 | 14FS+48eh | 0d |  | Supervisor; Riggers [400%]; Welders [200%]; Boilermakers [200%]; Trade Assistants [800%] | 2040h | 175,200 |
| 20 | 4.3 | Erect upper level gantry and platform |  | 1w | 2025-06-19 | 2025-06-26 | 19 | 0d |  | Supervisor; Riggers [200%]; Welders; Boilermakers; Trade Assistants [400%] | 360h | 31,200 |
| 21 | 4.4 | Install Elevator |  | 1w | 2025-06-26 | 2025-07-03 | 20 | 15.25d | 14d | Supervisor; Electrician; Riggers [200%]; Welders | 200h | 22,000 |
| 22 | 4.5 | Install Electrical wiring |  | 1w | 2025-06-26 | 2025-07-03 | 20 | 0d |  | Electrician | 40h | 6,000 |
| 23 | 4.6 | Test Elevator and related systems |  | 2d | 2025-07-03 | 2025-07-07 | 22 | 12.25d | 0d | Supervisor; Electrician; Riggers | 48h | 5,600 |
| 24 | 4.7 | Approvals for Elevator systems |  | 1d | 2025-07-07 | 2025-07-08 | 23 | 12.25d | 11d | Supervisor; Admin Assistant; Building Inspector | 24h | 3,960 |
| 25 | 4.8 | Installation of upper gantry winch |  | 1w | 2025-06-26 | 2025-07-03 | 22SS | 0d |  | Supervisor; Electrician; Riggers; Crane Hire Subcontractor | 160h | 14,000 |
| 26 | 4.9 | Installation of drainage pump |  | 1w | 2025-07-03 | 2025-07-10 | 22 | 10.25d | 9d | Plumbers [200%] | 80h | 8,000 |
| 27 | 4.10 | Fit Diving Boards |  | 3d | 2025-07-03 | 2025-07-08 | 25 | 0d |  | Supervisor; Riggers; Trade Assistants | 72h | 6,480 |
| 28 | 4.11 | Test Diving Board Capacities |  | 1.6w | 2025-07-08 | 2025-07-22 | 27 | 0d |  | Testers [400%] | 320h | 48,000 |
| 29 | 4.12 | Final Inspections |  | 1d | 2025-07-22 | 2025-07-23 | 28 | 0d |  | Supervisor; Admin Assistant; Building Inspector | 24h | 3,960 |
| 30 | 4.13 | Construction completed | milestone | 0d | 2025-07-23 | 2025-07-23 | 18, 21, 23, 24, 26, 29 | 1.25d |  |  |  |  |

| ID | WBS | Task | Type | Duration | Start | Finish | Predecessors | Total slack | Resources | Work | Cost |
| --- | --- | --- | --- | --- | --- | --- | --- | --- | --- | --- | --- |
| 31 | 5 | **Open Day** |  | 2d | 2025-07-23 | 2025-07-24 |  | 0d |  | 18h | 1,710 |
| 32 | 5.1 | Invite guests to Open Day |  | 2d | 2025-07-23 | 2025-07-24 | 29FS-7.5% | 0d | Admin Assistant | 16h | 1,520 |
| 33 | 5.2 | Invite political guests to opening |  | 2h | 2025-07-24 | 2025-07-24 | 32FF | 0d | Admin Assistant | 2h | 190 |
| 34 | 5.3 | Open Day | milestone | 0d | 2025-07-24 | 2025-07-24 | 33, 32 | 0d |  |  |  |
