# Best selling Novel Schedule

Schedule from MS Project, 2025-04-07 to 2025-12-01.

## Calendars

- Standard: Mon-Fri 08:00-12:00, 13:00-17:00; Sat-Sun off.

## Schedule

| ID | WBS | Task | Type | Duration | Start | Finish | Predecessors | Total slack |
| --- | --- | --- | --- | --- | --- | --- | --- | --- |
| 1 | 1 | **Acquisition** |  | 25d | 2025-04-07 | 2025-05-09 |  | 0d |
| 2 | 1.1 | Manuscript received | milestone | 0d | 2025-04-07 | 2025-04-07 |  | 0d |
| 3 | 1.2 | Content edit |  | 15d | 2025-04-07 | 2025-04-25 | 2 | 0d |
| 4 | 1.3 | Author review of content edit |  | 10d | 2025-04-28 | 2025-05-09 | 3 | 0d |
| 5 | 1.4 | Handoff to Editorial | milestone | 0d | 2025-05-09 | 2025-05-09 | 4 | 0d |
| 6 | 2 | **Editorial** |  | 35d | 2025-05-12 | 2025-06-27 | 1 | 0d |
| 7 | 2.1 | Organize manuscript for copyedit |  | 5d | 2025-05-12 | 2025-05-16 |  | 0d |
| 8 | 2.2 | Copyedit |  | 15d | 2025-05-19 | 2025-06-06 | 7 | 0d |
| 9 | 2.3 | Author review of copyedit |  | 10d | 2025-06-09 | 2025-06-20 | 8 | 0d |
| 10 | 2.4 | Copyedit incorp |  | 5d | 2025-06-23 | 2025-06-27 | 9 | 0d |
| 11 | 2.5 | Handoff to Production | milestone | 0d | 2025-06-27 | 2025-06-27 | 10 | 0d |
| 12 | 3 | **Design and Production** |  | 70d | 2025-06-30 | 2025-10-03 | 6 | 0d |
| 13 | 3.1 | Set pages |  | 15d | 2025-06-30 | 2025-07-18 |  | 0d |
| 14 | 3.2 | Interior illustration design |  | 15d | 2025-07-21 | 2025-08-08 | 13 | 0d |
| 15 | 3.3 | **1st Pages review** |  | 25d | 2025-08-11 | 2025-09-12 | 14 | 0d |
| 16 | 3.3.1 | Proofread and index |  | 10d | 2025-08-11 | 2025-08-22 |  | 0d |
| 17 | 3.3.2 | Incorporate 1st Pages review |  | 5d | 2025-08-25 | 2025-08-29 | 16 | 0d |
| 18 | 3.3.3 | Send proofed pages to Production | milestone | 0d | 2025-08-29 | 2025-08-29 | 17 | 0d |
| 19 | 3.3.4 | Enter page corrections and index |  | 5d | 2025-09-01 | 2025-09-05 | 18 | 0d |
| 20 | 3.3.5 | Cover design |  | 5d | 2025-09-08 | 2025-09-12 | 19 | 0d |
| 21 | 3.4 | **2nd Pages review** |  | 10d | 2025-09-15 | 2025-09-26 |  | 0d |
| 22 | 3.4.1 | Proof and review |  | 5d | 2025-09-15 | 2025-09-19 | 20 | 0d |
| 23 | 3.4.2 | Send proofed pages to Production | milestone | 0d | 2025-09-19 | 2025-09-19 | 22 | 0d |
| 24 | 3.4.3 | Final review |  | 5d | 2025-09-22 | 2025-09-26 | 23 | 0d |

| ID | WBS | Task | Type | Duration | Start | Finish | Predecessors | Total slack |
| --- | --- | --- | --- | --- | --- | --- | --- | --- |
| 25 | 3.5 | **Design book's companion website** |  | 5d | 2025-09-29 | 2025-10-03 | 24 | 0d |
| 26 | 3.5.1 | Create mockup |  | 3d | 2025-09-29 | 2025-10-01 |  | 0d |
| 27 | 3.5.2 | Review with author |  | 2d | 2025-10-02 | 2025-10-03 | 26 | 0d |
| 28 | 3.6 | Design and Production complete | milestone | 0d | 2025-10-03 | 2025-10-03 | 27, 24, 20, 14 | 41d |
| 29 | 4 | **Color prep and printing** |  | 41d | 2025-10-06 | 2025-12-01 | 25 | 0d |
| 30 | 4.1 | Send to printer |  | 1d | 2025-10-06 | 2025-10-06 | 21 | 0d |
| 31 | 4.2 | Generate proofs |  | 10d | 2025-10-07 | 2025-10-20 | 30 | 0d |
| 32 | 4.3 | Print and ship |  | 30d | 2025-10-21 | 2025-12-01 | 31 | 0d |
