# CKM Office Renovation

Schedule from MS Project, 2025-04-07 to 2025-04-23, 7 hours a day, costs in $.
Office Renovation Project
Corporate Knowledge Management

## Calendars

- Standard: Mon-Fri 09:00-13:00, 14:00-17:00; Sat-Sun off.

## Resources

| Resource | Group | Rate | Cost per use |
| --- | --- | --- | --- |
| Carpenter | Contractor | 35 |  |
| Carpet Contractor | Contractor |  |  |
| Fit-out Consultant | Consultant | 65 | 50 |
| IT Consultant | Contractor | 80 |  |
| Labourer | Contractor | 20 |  |
| Management | Staff | 100 |  |
| Painter | Contractor | 35 |  |
| Plasterer | Contractor | 35 |  |
| Project Manager | Staff | 88 |  |
| Staff | Staff | 50 |  |
| Telecommunications consultant | Consultant | 60 |  |
| Admin Assistant | Staff | 45 |  |

## Schedule

| ID | WBS | Task | Type | Duration | Start | Finish | Predecessors | Total slack | Free slack | Resources | Work | Cost |
| --- | --- | --- | --- | --- | --- | --- | --- | --- | --- | --- | --- | --- |
| 1 | 1 | **Restructure Office** |  | 13d | 2025-04-07 | 2025-04-23 |  | 0d |  |  | 64.5h | 18,025 |
| 2 | 1.1 | Erect New Walls |  | 7h | 2025-04-07 | 2025-04-09 |  | 1d |  | Carpenter [200%] | 14h | 490 |
| 3 | 1.2 | Gyprock, Plaster & Finish |  | 14h | 2025-04-10 | 2025-04-14 | 2 | 0d |  | Plasterer | 14h | 10,490 |
| 4 | 1.3 | Install Network Points |  | 5h | 2025-04-15 | 2025-04-15 | 3FS+1ed | 0.5d | 0d | IT Consultant | 5h | 400 |
| 5 | 1.4 | Install Phone Connections |  | 0.5d | 2025-04-15 | 2025-04-15 | 4SS | 0.5d |  | Telecommunications consultant | 3.5h | 700 |
| 6 | 1.5 | Re-Paint |  | 1d | 2025-04-16 | 2025-04-18 | 5 | 0d |  | Painter | 7h | 245 |
| 7 | 1.6 | Carpet |  | 1d | 2025-04-19 | 2025-04-19 | 6FS+1ed | 0d |  | Carpet Contractor | 7h | 5,000 |
| 8 | 1.7 | Install New Furniture |  | 1d | 2025-04-21 | 2025-04-23 | 7 | 0d |  | Labourer | 7h | 140 |
| 9 | 1.8 | Install New PCs |  | 1d | 2025-04-23 | 2025-04-23 | 8 | 0d |  | IT Consultant | 7h | 560 |
| 10 | 1.9 | Refit Office Complete | milestone | 0d | 2025-04-23 | 2025-04-23 | 9 | 0d |  |  |  |  |
