# Project A

Schedule from MS Project, 2025-04-07 to 2025-07-03.
Templates

## Calendars

- Standard: Mon-Fri 08:00-12:00, 13:00-17:00; Sat-Sun off.

## Schedule

| ID | Task | Duration | Start | Finish | Predecessors | Total slack |
| --- | --- | --- | --- | --- | --- | --- |
| 1 | Architectural Plans | 2w | 2025-04-07 | 2025-04-18 |  | 0d |
| 2 | Council approval | 1d | 2025-04-21 | 2025-04-21 | 1 | 0d |
| 3 | Site preparation | 3d | 2025-05-12 | 2025-05-14 | 2FS+14d | 0d |
| 4 | Delivery of Materials | 1d | 2025-05-12 | 2025-05-12 | 3SS | 38d |
| 5 | Lay Foundations | 2d | 2025-05-15 | 2025-05-16 | 3 | 0d |
| 6 | External Plumbing | 1d | 2025-05-19 | 2025-05-19 | 5 | 0d |
| 7 | Pour foundation slab | 1d | 2025-05-20 | 2025-05-20 | 6 | 0d |
| 8 | Erect house frame | 3d | 2025-05-21 | 2025-05-23 | 7 | 0d |
| 9 | Roofing tiles | 3d | 2025-05-26 | 2025-05-28 | 8 | 0d |
| 10 | Brick Walls | 5d | 2025-05-29 | 2025-06-04 | 9 | 0d |
| 11 | Fit Windows & Doors | 2d | 2025-06-05 | 2025-06-06 | 10 | 0d |
| 12 | Electrical Cables | 1d | 2025-06-09 | 2025-06-09 | 11 | 0d |
| 13 | Internal Plumbing | 1d | 2025-06-09 | 2025-06-09 | 12SS | 0d |
| 14 | Plaster Walls | 5d | 2025-06-10 | 2025-06-16 | 13 | 0d |
| 15 | Internal Doors and Trim | 4d | 2025-06-17 | 2025-06-20 | 14 | 0d |
| 16 | Install Kitchen | 2d | 2025-06-23 | 2025-06-24 | 15 | 0d |
| 17 | Install Bathroom | 2d | 2025-06-23 | 2025-06-24 | 16SS | 0d |
| 18 | Final Electrical Fittings | 2d | 2025-06-25 | 2025-06-26 | 17 | 0d |
| 19 | Final Plumbing Fittings | 2d | 2025-06-25 | 2025-06-26 | 18SS | 0d |
| 20 | Paint | 5d | 2025-06-27 | 2025-07-03 | 19 | 0d |
