# Project B

Schedule from MS Project, 2025-04-14 to 2025-07-10.
House

## Calendars

- Standard: Mon-Fri 08:00-12:00, 13:00-17:00; Sat-Sun off.

## Schedule

| ID | Task | Duration | Start | Finish | Predecessors | Total slack |
| --- | --- | --- | --- | --- | --- | --- |
| 1 | Architectural Plans | 2w | 2025-04-14 | 2025-04-25 |  | 0d |
| 2 | Council approval | 1d | 2025-04-28 | 2025-04-28 | 1 | 0d |
| 3 | Site preparation | 3d | 2025-05-19 | 2025-05-21 | 2FS+14d | 0d |
| 4 | Delivery of Materials | 1d | 2025-05-19 | 2025-05-19 | 3SS | 38d |
| 5 | Lay Foundations | 2d | 2025-05-22 | 2025-05-23 | 3 | 0d |
| 6 | External Plumbing | 1d | 2025-05-26 | 2025-05-26 | 5 | 0d |
| 7 | Pour foundation slab | 1d | 2025-05-27 | 2025-05-27 | 6 | 0d |
| 8 | Erect house frame | 3d | 2025-05-28 | 2025-05-30 | 7 | 0d |
| 9 | Roofing tiles | 3d | 2025-06-02 | 2025-06-04 | 8 | 0d |
| 10 | Brick Walls | 5d | 2025-06-05 | 2025-06-11 | 9 | 0d |
| 11 | Fit Windows & Doors | 2d | 2025-06-12 | 2025-06-13 | 10 | 0d |
| 12 | Electrical Cables | 1d | 2025-06-16 | 2025-06-16 | 11 | 0d |
| 13 | Internal Plumbing | 1d | 2025-06-16 | 2025-06-16 | 12SS | 0d |
| 14 | Plaster Walls | 5d | 2025-06-17 | 2025-06-23 | 13 | 0d |
| 15 | Internal Doors and Trim | 4d | 2025-06-24 | 2025-06-27 | 14 | 0d |
| 16 | Install Kitchen | 2d | 2025-06-30 | 2025-07-01 | 15 | 0d |
| 17 | Install Bathroom | 2d | 2025-06-30 | 2025-07-01 | 16SS | 0d |
| 18 | Final Electrical Fittings | 2d | 2025-07-02 | 2025-07-03 | 17 | 0d |
| 19 | Final Plumbing Fittings | 2d | 2025-07-02 | 2025-07-03 | 18SS | 0d |
| 20 | Paint | 5d | 2025-07-04 | 2025-07-10 | 19 | 0d |
