# Project D

Schedule from MS Project, 2025-04-28 to 2025-07-24.
House

## Calendars

- Standard: Mon-Fri 08:00-12:00, 13:00-17:00; Sat-Sun off.

## Schedule

| ID | Task | Duration | Start | Finish | Predecessors | Total slack |
| --- | --- | --- | --- | --- | --- | --- |
| 1 | Architectural Plans | 2w | 2025-04-28 | 2025-05-09 |  | 0d |
| 2 | Council approval | 1d | 2025-05-12 | 2025-05-12 | 1 | 0d |
| 3 | Site preparation | 3d | 2025-06-02 | 2025-06-04 | 2FS+14d | 0d |
| 4 | Delivery of Materials | 1d | 2025-06-02 | 2025-06-02 | 3SS | 38d |
| 5 | Lay Foundations | 2d | 2025-06-05 | 2025-06-06 | 3 | 0d |
| 6 | External Plumbing | 1d | 2025-06-09 | 2025-06-09 | 5 | 0d |
| 7 | Pour foundation slab | 1d | 2025-06-10 | 2025-06-10 | 6 | 0d |
| 8 | Erect house frame | 3d | 2025-06-11 | 2025-06-13 | 7 | 0d |
| 9 | Roofing tiles | 3d | 2025-06-16 | 2025-06-18 | 8 | 0d |
| 10 | Brick Walls | 5d | 2025-06-19 | 2025-06-25 | 9 | 0d |
| 11 | Fit Windows & Doors | 2d | 2025-06-26 | 2025-06-27 | 10 | 0d |
| 12 | Electrical Cables | 1d | 2025-06-30 | 2025-06-30 | 11 | 0d |
| 13 | Internal Plumbing | 1d | 2025-06-30 | 2025-06-30 | 12SS | 0d |
| 14 | Plaster Walls | 5d | 2025-07-01 | 2025-07-07 | 13 | 0d |
| 15 | Internal Doors and Trim | 4d | 2025-07-08 | 2025-07-11 | 14 | 0d |
| 16 | Install Kitchen | 2d | 2025-07-14 | 2025-07-15 | 15 | 0d |
| 17 | Install Bathroom | 2d | 2025-07-14 | 2025-07-15 | 16SS | 0d |
| 18 | Final Electrical Fittings | 2d | 2025-07-16 | 2025-07-17 | 17 | 0d |
| 19 | Final Plumbing Fittings | 2d | 2025-07-16 | 2025-07-17 | 18SS | 0d |
| 20 | Paint | 5d | 2025-07-18 | 2025-07-24 | 19 | 0d |
