# Reports

Schedule from MS Project, 2025-04-07 to 2025-05-30, 7 hours a day, costs in $, A marks actual dates.

## Calendars

- Standard: Mon-Fri 09:00-12:00, 13:00-17:00; Sat-Sun off.

## Resources

| Resource | Unit | Rate |
| --- | --- | --- |
| Project Manager |  | 300 |
| Management |  | 250 |
| Staff |  | 130 |
| Fit-out Consultant |  | 220 |
| Telecommunications consultant |  | 275 |
| IT Consultant |  | 165 |
| Carpenter |  | 120 |
| Plasterer |  | 160 |
| Paint | litre | 60 |
| Painter |  | 175 |
| Carpet | lin metre | 125 |
| Carpet Contractor |  | 100 |
| Labourer |  | 100 |
| Admin Assistant |  | 110 |

## Schedule

| ID | WBS | Task | Type | Duration | Start | Finish | Predecessors | Complete | Remaining | Baseline start | Baseline finish | Baseline duration | Total slack | Free slack | Deadline | Resources | Work | Actual work | Cost | Baseline cost | Actual cost |
| --- | --- | --- | --- | --- | --- | --- | --- | --- | --- | --- | --- | --- | --- | --- | --- | --- | --- | --- | --- | --- | --- |
| 1 | 1 | **Planning & Research** |  | 12.43d | 2025-04-07 09:00 A | 2025-04-23 13:00 A |  | 100% |  | 2025-04-07 09:00 | 2025-04-23 13:00 | 12.43d |  |  |  |  | 38h | 38h | 11,400 | 11,400 | 11,400 |
| 2 | 1.1 | Develop Requirements Documentation |  | 1d | 2025-04-07 09:00 A | 2025-04-07 17:00 A |  | 100% |  | 2025-04-07 09:00 | 2025-04-07 17:00 | 1d |  |  | 2025-04-08 17:00 | Project Manager | 7h | 7h | 2,100 | 2,100 | 2,100 |
| 3 | 1.2 | Fit-Out Consultant Research |  | 1d | 2025-04-08 09:00 A | 2025-04-08 17:00 A | 2 | 100% |  | 2025-04-08 09:00 | 2025-04-08 17:00 | 1d |  |  |  | Project Manager | 7h | 7h | 2,100 | 2,100 | 2,100 |
| 4 | 1.3 | Telecommunications Consultant Research |  | 1d | 2025-04-09 09:00 A | 2025-04-09 17:00 A | 3 | 100% |  | 2025-04-09 09:00 | 2025-04-09 17:00 | 1d |  |  |  | Project Manager | 7h | 7h | 2,100 | 2,100 | 2,100 |
| 5 | 1.4 | IT Network Contractor Research |  | 1d | 2025-04-10 09:00 A | 2025-04-10 17:00 A | 4 | 100% |  | 2025-04-10 09:00 | 2025-04-10 17:00 | 1d |  |  |  | Project Manager | 7h | 7h | 2,100 | 2,100 | 2,100 |
| 6 | 1.5 | Building Contractors Research |  | 1d | 2025-04-11 09:00 A | 2025-04-11 17:00 A | 5 | 100% |  | 2025-04-11 09:00 | 2025-04-11 17:00 | 1d |  |  |  | Project Manager | 7h | 7h | 2,100 | 2,100 | 2,100 |
| 7 | 1.6 | Submit Requirements to Resources & Request Quotes |  | 2h | 2025-04-14 09:00 A | 2025-04-14 11:00 A | 6 | 100% |  | 2025-04-14 09:00 | 2025-04-14 11:00 | 2h |  |  |  | Project Manager | 2h | 2h | 600 | 600 | 600 |
| 8 | 1.7 | Quotes Received |  | 1h | 2025-04-23 11:00 A | 2025-04-23 12:00 A | 7FS+5d | 100% |  | 2025-04-23 11:00 | 2025-04-23 12:00 | 1h |  |  |  | Project Manager | 1h | 1h | 300 | 300 | 300 |
| 9 | 1.8 | Planning & Research Complete | milestone | 0d | 2025-04-23 13:00 A | 2025-04-23 13:00 A | 8 | 100% |  | 2025-04-23 13:00 | 2025-04-23 13:00 | 0d |  |  |  |  |  |  |  |  |  |
| 10 | 2 | **Management Approval** |  | 1.79d | 2025-04-23 13:00 A | 2025-04-25 10:30 A |  | 100% |  | 2025-04-23 13:00 | 2025-04-25 10:30 | 1.79d |  |  |  |  | 13.5h | 13.5h | 4,000 | 4,000 | 4,000 |
| 11 | 2.1 | Consolidate Quotes and develop proposal |  | 1.5d | 2025-04-23 13:00 A | 2025-04-24 16:30 A | 9 | 100% |  | 2025-04-23 13:00 | 2025-04-24 16:30 | 1.5d |  |  |  | Project Manager | 10.5h | 10.5h | 3,150 | 3,150 | 3,150 |
| 12 | 2.2 | Develop Project Plan & Durations |  | 1h | 2025-04-24 16:30 A | 2025-04-25 09:30 A | 11 | 100% |  | 2025-04-24 16:30 | 2025-04-25 09:30 | 1h |  |  |  | Project Manager | 1h | 1h | 300 | 300 | 300 |
| 13 | 2.3 | Submit Project Plan & Costs to Management |  | 1h | 2025-04-25 09:30 A | 2025-04-25 10:30 A | 12 | 100% |  | 2025-04-25 09:30 | 2025-04-25 10:30 | 1h |  |  |  | Project Manager; Management | 2h | 2h | 550 | 550 | 550 |
| 14 | 2.4 | Management Approval Received | milestone | 0d | 2025-04-25 10:30 A | 2025-04-25 10:30 A | 13 | 100% |  | 2025-04-25 10:30 | 2025-04-25 10:30 | 0d |  |  |  |  |  |  |  |  |  |
| 15 | 3 | **Refit Office** |  | 21.79d | 2025-04-25 10:30 A | 2025-05-26 17:00 |  | 18% | 17.84d | 2025-04-25 10:30 | 2025-05-26 17:00 | 21.79d | 0.5d |  |  |  | 162h | 57.5h | 64,125 | 64,125 | 12,045 |
| 16 | 3.1 | Appoint Resources |  | 0.5d | 2025-04-25 10:30 A | 2025-04-25 15:00 A | 14 | 100% |  | 2025-04-25 10:30 | 2025-04-25 15:00 | 0.5d |  |  |  | Project Manager | 3.5h | 3.5h | 1,050 | 1,050 | 1,050 |
| 17 | 3.2 | Staff Briefing |  | 0.5d | 2025-04-25 15:00 A | 2025-04-28 10:30 A | 16 | 100% |  | 2025-04-25 15:00 | 2025-04-28 10:30 | 0.5d |  |  |  | Project Manager; Staff [700%] | 28h | 28h | 4,235 | 4,235 | 4,235 |
| 18 | 3.3 | **Fit-Out Consultations** |  | 2.86d | 2025-04-28 10:30 A | 2025-05-01 09:30 A |  | 100% |  | 2025-04-28 10:30 | 2025-05-01 09:30 | 2.86d |  |  |  |  | 26h | 26h | 6,760 | 6,760 | 6,760 |
| 19 | 3.3.1 | Office Space / Structure Plan |  | 1d | 2025-04-28 10:30 A | 2025-04-29 10:30 A | 17 | 100% |  | 2025-04-28 10:30 | 2025-04-29 10:30 | 1d |  |  |  | Fit-out Consultant; Project Manager | 14h | 14h | 3,640 | 3,640 | 3,640 |
| 20 | 3.3.2 | Select & Order Carpet |  | 2h | 2025-04-30 10:30 A | 2025-04-30 13:30 A | 19 | 100% |  | 2025-04-30 10:30 | 2025-04-30 13:30 | 2h |  |  |  | Fit-out Consultant; Project Manager | 4h | 4h | 1,040 | 1,040 | 1,040 |
| 21 | 3.3.3 | Select & Order Paint |  | 2h | 2025-04-30 13:30 A | 2025-04-30 15:30 A | 20 | 100% |  | 2025-04-30 13:30 | 2025-04-30 15:30 | 2h |  |  |  | Fit-out Consultant; Project Manager | 4h | 4h | 1,040 | 1,040 | 1,040 |
| 22 | 3.3.4 | Select & Order Office Furniture |  | 2h | 2025-04-30 15:30 A | 2025-05-01 09:30 A | 21 | 100% |  | 2025-04-30 15:30 | 2025-05-01 09:30 | 2h |  |  |  | Fit-out Consultant; Project Manager | 4h | 4h | 1,040 | 1,040 | 1,040 |
| 23 | 3.4 | **Telecommuncations Consultations** |  | 1d | 2025-05-01 09:30 | 2025-05-02 09:30 |  |  |  | 2025-05-01 09:30 | 2025-05-02 09:30 | 1d | 1.71d |  |  |  | 10.5h |  | 3,062.5 | 3,062.5 |  |
| 24 | 3.4.1 | Design Telephone Access Points Map |  | 0.5d | 2025-05-01 09:30 | 2025-05-01 14:00 | 22 |  |  | 2025-05-01 09:30 | 2025-05-01 14:00 | 0.5d | 1.71d | 0d |  | Project Manager; Telecommunications consultant | 7h |  | 2,012.5 | 2,012.5 |  |
| 25 | 3.4.2 | Select & Order New PABX |  | 0.5d | 2025-05-01 14:00 | 2025-05-02 09:30 | 24 |  |  | 2025-05-01 14:00 | 2025-05-02 09:30 | 0.5d | 1.71d | 0d |  | Project Manager | 3.5h |  | 1,050 | 1,050 |  |

| ID | WBS | Task | Type | Duration | Start | Finish | Predecessors | Baseline start | Baseline finish | Baseline duration | Total slack | Free slack | Resources | Work | Cost | Baseline cost |
| --- | --- | --- | --- | --- | --- | --- | --- | --- | --- | --- | --- | --- | --- | --- | --- | --- |
| 26 | 3.5 | **IT Networking Consultations** |  | 6.79d | 2025-05-02 09:30 | 2025-05-12 16:00 |  | 2025-05-02 09:30 | 2025-05-12 16:00 | 6.79d | 1.71d |  |  | 16h | 23,382.5 | 23,382.5 |
| 27 | 3.5.1 | Design Network Access Points Map |  | 0.5d | 2025-05-02 09:30 | 2025-05-02 14:00 | 22, 25 | 2025-05-02 09:30 | 2025-05-02 14:00 | 0.5d | 1.71d | 0d | IT Consultant; Project Manager | 7h | 1,627.5 | 1,627.5 |
| 28 | 3.5.2 | Select & Order New PCs |  | 1h | 2025-05-02 14:00 | 2025-05-02 15:00 | 27 | 2025-05-02 14:00 | 2025-05-02 15:00 | 1h | 1.71d | 0d | Project Manager | 1h | 300 | 300 |
| 29 | 3.5.3 | New PCs Arrive |  | 1h | 2025-05-09 15:00 | 2025-05-09 16:00 | 28FS+5d | 2025-05-09 15:00 | 2025-05-09 16:00 | 1h | 1.71d | 0d | Project Manager | 1h | 20,300 | 20,300 |
| 30 | 3.5.4 | Configure SOE on PCs |  | 1d | 2025-05-09 16:00 | 2025-05-12 16:00 | 29 | 2025-05-09 16:00 | 2025-05-12 16:00 | 1d | 1.71d | 0d | IT Consultant | 7h | 1,155 | 1,155 |
| 31 | 3.6 | **Restructure Office** |  | 17d | 2025-05-02 06:00 | 2025-05-26 17:00 |  | 2025-05-02 06:00 | 2025-05-26 17:00 | 17d | 0.5d |  |  | 78h | 25,635 | 25,635 |
| 32 | 3.6.1 | Erect New Walls |  | 7h | 2025-05-02 06:00 | 2025-05-03 11:00 | 22 | 2025-05-02 06:00 | 2025-05-03 11:00 | 7h | 3d | 0d | Carpenter [200%] | 14h | 1,680 | 1,680 |
| 33 | 3.6.2 | Gyprock, Plaster & Finish |  | 14h | 2025-05-03 12:00 | 2025-05-08 08:00 | 32 | 2025-05-03 12:00 | 2025-05-08 08:00 | 14h | 3d | 2d | Plasterer | 14h | 12,240 | 12,240 |
| 34 | 3.6.3 | Install Network Points |  | 5h | 2025-05-12 16:00 | 2025-05-13 14:00 | 30, 33FS+1ed | 2025-05-12 16:00 | 2025-05-13 14:00 | 5h | 1.71d | 0d | IT Consultant | 5h | 825 | 825 |
| 35 | 3.6.4 | Install Phone Connections |  | 3h | 2025-05-12 16:00 | 2025-05-13 11:00 | 34SS | 2025-05-12 16:00 | 2025-05-13 11:00 | 3h | 1.71d | 0.71d | Telecommunications consultant | 3h |  |  |
| 36 | 3.6.5 | Re-Paint |  | 2d | 2025-05-14 06:00 | 2025-05-17 13:00 | 35 | 2025-05-14 06:00 | 2025-05-17 13:00 | 2d | 0d |  | Paint [1 litre]; Painter | 14h | 2,510 | 2,510 |
| 37 | 3.6.6 | Carpet |  | 2d | 2025-05-19 06:00 | 2025-05-23 08:00 | 36FS+1ed | 2025-05-19 06:00 | 2025-05-23 08:00 | 2d | 1d | 0d | Carpet [1 lin metre]; Carpet Contractor | 14h | 6,525 | 6,525 |
| 38 | 3.6.7 | Install New Furniture |  | 1d | 2025-05-23 08:00 | 2025-05-24 14:00 | 37 | 2025-05-23 08:00 | 2025-05-24 14:00 | 1d | 0d |  | Labourer | 7h | 700 | 700 |
| 39 | 3.6.8 | Install New PCs |  | 1d | 2025-05-26 09:00 | 2025-05-26 17:00 | 38 | 2025-05-26 09:00 | 2025-05-26 17:00 | 1d | 0.5d | 0d | IT Consultant | 7h | 1,155 | 1,155 |
| 40 | 3.6.9 | Refit Office Complete | milestone | 0d | 2025-05-26 17:00 | 2025-05-26 17:00 | 39 | 2025-05-26 17:00 | 2025-05-26 17:00 | 0d | 0.5d | 0d |  |  |  |  |
| 41 | 4 | **Office Move** |  | 14.14d | 2025-05-09 16:00 | 2025-05-30 07:00 |  | 2025-05-09 16:00 | 2025-05-30 07:00 | 14.14d | 0d |  |  | 221.5h | 29,160 | 29,160 |
| 42 | 4.1 | Order packing boxes |  | 1h | 2025-05-09 16:00 | 2025-05-09 17:00 | 29 | 2025-05-09 16:00 | 2025-05-09 17:00 | 1h | 11.5d | 11d | Admin Assistant | 1h | 110 | 110 |
| 43 | 4.2 | Staff Pack |  | 0.5d | 2025-05-27 09:00 | 2025-05-27 13:30 | 40, 42 | 2025-05-27 09:00 | 2025-05-27 13:30 | 0.5d | 0.5d | 0d | Project Manager; Staff [2000%] | 73.5h | 10,150 | 10,150 |
| 44 | 4.3 | Staff Move |  | 2d | 2025-05-27 13:30 | 2025-05-30 07:00 | 43 | 2025-05-27 13:30 | 2025-05-30 07:00 | 2d | 0d |  | Staff [2000%]; Labourer | 147h | 18,900 | 18,900 |
| 45 | 4.4 | Office Move Complete | milestone | 0d | 2025-05-30 07:00 | 2025-05-30 07:00 | 44 | 2025-05-30 07:00 | 2025-05-30 07:00 | 0d | 0d |  |  |  |  |  |
