# CKM Office Renovation

Schedule from MS Project, 2025-04-07 to 2025-06-05, 7 hours a day.
Office Renovation Project
Corporate Knowledge Management

## Calendars

- Standard: Mon-Fri 09:00-13:00, 14:00-17:00; Sat-Sun off.

## Resources

| Resource | Group |
| --- | --- |
| Admin Assistant | Staff |
| Carpenter | Contractor |
| Carpet Contractor | Contractor |
| Fit-out Consultant | Consultant |
| IT Consultant | Contractor |
| Labourer | Contractor |
| Management | Staff |
| Painter | Contractor |
| Staff | Staff |
| Telecommunications consultant | Consultant |
| Plasterer | Contractor |
| Project Manager | Staff |

## Schedule

| ID | WBS | Task | Type | Duration | Start | Finish | Predecessors | Total slack | Free slack | Resources | Work |
| --- | --- | --- | --- | --- | --- | --- | --- | --- | --- | --- | --- |
| 1 | 1 | **Planning & Research** |  | 15.5d | 2025-04-07 | 2025-04-28 |  | 1.29d |  |  | 7h |
| 2 | 1.1 | Develop Requirements Documentation |  | 1d | 2025-04-07 | 2025-04-07 |  | 1.29d | 0d | Project Manager | 7h |
| 3 | 1.2 | Fit-Out Consultant Research |  | 2d | 2025-04-08 | 2025-04-09 | 2 | 1.29d | 0d |  |  |
| 4 | 1.3 | Telecommunications Consultant Research |  | 2d | 2025-04-10 | 2025-04-11 | 3 | 1.29d | 0d |  |  |
| 5 | 1.4 | IT Network Contractor Research |  | 2d | 2025-04-14 | 2025-04-15 | 4 | 1.29d | 0d |  |  |
| 6 | 1.5 | Building Contractors Research |  | 2d | 2025-04-16 | 2025-04-17 | 5 | 1.29d | 0d |  |  |
| 7 | 1.6 | Submit Requirements to Resources & Request Quotes |  | 1d | 2025-04-18 | 2025-04-18 | 6 | 1.29d | 0d |  |  |
| 8 | 1.7 | Quotes Received |  | 0.5d | 2025-04-28 | 2025-04-28 | 7FS+5d | 1.29d | 0d |  |  |
| 9 | 1.8 | Planning & Research Complete | milestone | 0d | 2025-04-28 | 2025-04-28 | 8 | 1.29d | 0d |  |  |
| 10 | 2 | **Management Approval** |  | 4.14d | 2025-04-28 | 2025-05-02 |  | 1.29d |  |  |  |
| 11 | 2.1 | Consolidate Quotes and develop proposal |  | 2d | 2025-04-28 | 2025-04-30 | 9 | 1.29d | 0d |  |  |
| 12 | 2.2 | Develop Project Plan & Durations |  | 2d | 2025-04-30 | 2025-05-02 | 11 | 1.29d | 0d |  |  |
| 13 | 2.3 | Submit Project Plan & Costs to Management |  | 1h | 2025-05-02 | 2025-05-02 | 12 | 1.29d | 0d |  |  |
| 14 | 2.4 | Management Approval Received | milestone | 0d | 2025-05-02 | 2025-05-02 | 13 | 1.29d | 0d |  |  |
| 15 | 3 | **Refit Office** |  | 20.07d | 2025-05-02 | 2025-05-30 |  | 1.29d |  |  | 28h |
| 16 | 3.1 | Appoint Resources |  | 1d | 2025-05-02 | 2025-05-05 | 14 | 1.29d | 0d |  |  |
| 17 | 3.2 | Staff Briefing |  | 1h | 2025-05-05 | 2025-05-05 | 16 | 1.29d | 0d |  |  |
| 18 | 3.3 | **Fit-Out Consultations** |  | 2.5d | 2025-05-05 | 2025-05-08 |  | 1.29d |  |  |  |
| 19 | 3.3.1 | Office Space / Structure Plan |  | 1d | 2025-05-05 | 2025-05-06 | 17 | 1.29d | 0d |  |  |
| 20 | 3.3.2 | Select & Order Carpet |  | 0.5d | 2025-05-06 | 2025-05-07 | 19 | 1.29d | 0d |  |  |
| 21 | 3.3.3 | Select & Order Paint |  | 0.5d | 2025-05-07 | 2025-05-07 | 20 | 1.29d | 0d |  |  |
| 22 | 3.3.4 | Select & Order Office Furniture |  | 0.5d | 2025-05-07 | 2025-05-08 | 21 | 1.29d | 0d |  |  |
| 23 | 3.4 | **Telecommuncations Consultations** |  | 2d | 2025-05-08 | 2025-05-12 |  | 17.71d |  |  |  |
| 24 | 3.4.1 | Design Telephone Access Points Map |  | 1d | 2025-05-08 | 2025-05-09 | 22 | 17.71d | 0d |  |  |
| 25 | 3.4.2 | Select & Order New PABX |  | 1d | 2025-05-09 | 2025-05-12 | 24 | 17.71d |  |  |  |

| ID | WBS | Task | Type | Duration | Start | Finish | Predecessors | Total slack | Free slack | Resources | Work |
| --- | --- | --- | --- | --- | --- | --- | --- | --- | --- | --- | --- |
| 26 | 3.5 | **IT Networking Consultations** |  | 8.14d | 2025-05-08 | 2025-05-20 |  | 1.29d |  |  |  |
| 27 | 3.5.1 | Design Network Access Points Map |  | 1d | 2025-05-08 | 2025-05-09 | 22 | 1.29d | 0d |  |  |
| 28 | 3.5.2 | Select & Order New PCs |  | 1d | 2025-05-09 | 2025-05-12 | 27 | 1.29d | 0d |  |  |
| 29 | 3.5.3 | New PCs Arrive |  | 1h | 2025-05-19 | 2025-05-19 | 28FS+5d | 1.29d | 0d |  |  |
| 30 | 3.5.4 | Configure SOE on PCs |  | 1d | 2025-05-19 | 2025-05-20 | 29 | 1.29d | 0d |  |  |
| 31 | 3.6 | **Restructure Office** |  | 8.29d | 2025-05-20 | 2025-05-30 |  | 1.29d |  |  | 28h |
| 32 | 3.6.1 | Erect New Walls |  | 7h | 2025-05-20 | 2025-05-21 | 30 | 1.29d | 0d | Carpenter [200%] | 14h |
| 33 | 3.6.2 | Gyprock, Plaster & Finish |  | 7h | 2025-05-21 | 2025-05-22 | 32 | 1.29d | 0d | Plasterer [200%] | 14h |
| 34 | 3.6.3 | Install Network Points |  | 5h | 2025-05-23 | 2025-05-26 | 33FS+1d | 1.29d | 0d |  |  |
| 35 | 3.6.4 | Install Phone Connections |  | 2h | 2025-05-23 | 2025-05-23 | 34SS | 1.29d | 0d |  |  |
| 36 | 3.6.5 | Re-Paint |  | 1d | 2025-05-23 | 2025-05-26 | 35 | 1.29d | 0d |  |  |
| 37 | 3.6.6 | Carpet |  | 1d | 2025-05-27 | 2025-05-28 | 36FS+1d | 1.29d | 0d |  |  |
| 38 | 3.6.7 | Install New Furniture |  | 1d | 2025-05-28 | 2025-05-29 | 37 | 1.29d | 0d |  |  |
| 39 | 3.6.8 | Install New PCs |  | 1d | 2025-05-29 | 2025-05-30 | 38 | 1.29d | 0d |  |  |
| 40 | 3.6.9 | Refit Office Complete | milestone | 0d | 2025-05-30 | 2025-05-30 | 39 | 1.29d | 0.29d |  |  |
| 41 | 4 | **Office Move** |  | 4.29d | 2025-05-29 | 2025-06-05 |  | 0d |  |  |  |
| 42 | 4.1 | Order packing boxes |  | 1h | 2025-05-29 | 2025-05-29 | 38 | 4.14d |  |  |  |
| 43 | 4.2 | Staff Pack | manual | 1d | 2025-06-02 | 2025-06-02 | 40 |  |  |  |  |
| 44 | 4.3 | Staff Move | manual | 1d | 2025-06-03 | 2025-06-03 | 43 |  |  |  |  |
| 45 | 4.4 | Office Move Complete | milestone, manual | 0d | 2025-06-05 | 2025-06-05 | 44 |  |  |  |  |
