# Revision Lab

Schedule from MS Project, 2025-04-07 to 2025-06-25.

## Calendars

- Standard: Mon-Fri 08:00-12:00, 13:00-17:00; Sat-Sun off.

## Resources

| Resource |
| --- |
| ACME Couriers |
| Corporate Printing Co |
| Designer |
| Artists |
| Drafter |
| Building Contractors |
| Cabinetmakers |
| Admin Assistant |
| Project Manager |
| Graphic Designer |
| Accountant |
| Sales staff |
| Marketing Manager |
| Marketing Assistant |
| OH&S Officer |
| Sales Manager |

## Schedule

| ID | WBS | Task | Type | Duration | Start | Finish | Predecessors | Total slack | Free slack | Resources | Work |
| --- | --- | --- | --- | --- | --- | --- | --- | --- | --- | --- | --- |
| 1 | 1 | **Planning Stage** |  | 17.81d | 2025-04-07 | 2025-04-30 |  | 1.59d |  |  | 135h |
| 2 | 1.1 | Apply for Exhibition permit |  | 7.5h | 2025-04-07 | 2025-04-07 |  | 1.59d | 0d | Admin Assistant | 7.5h |
| 3 | 1.2 | Await approval |  | 75h | 2025-04-07 | 2025-04-21 | 2 | 1.59d | 0d |  |  |
| 4 | 1.3 | Engage Building Contractor |  | 7.5h | 2025-04-21 | 2025-04-22 | 3 | 1.59d | 0d | Admin Assistant; Project Manager | 15h |
| 5 | 1.4 | Site visit and measurement of area |  | 7.5h | 2025-04-22 | 2025-04-23 | 4 | 1.59d | 0d | Building Contractors; Project Manager | 15h |
| 6 | 1.5 | Design Stand Layout |  | 22.5h | 2025-04-23 | 2025-04-25 | 5 | 1.59d | 0d | Designer; Drafter | 45h |
| 7 | 1.6 | Gain layout approval |  | 15h | 2025-04-28 | 2025-04-29 | 6 | 1.59d | 0d | Designer; Drafter; Project Manager | 45h |
| 8 | 1.7 | Print Design blueprints |  | 7.5h | 2025-04-29 | 2025-04-30 | 7 | 1.59d | 0d | Drafter | 7.5h |
| 9 | 1.8 | Planning Stage Complete | milestone | 0d | 2025-04-30 | 2025-04-30 | 8 | 1.59d | 0d |  |  |
| 10 | 2 | **Marketing Materials** |  | 17.97d | 2025-04-30 | 2025-05-26 |  | 1.59d |  |  | 260h |
| 11 | 2.1 | Requirements Gathering |  | 11.25h | 2025-04-30 | 2025-05-02 | 9 | 1.59d | 0d | Marketing Assistant; Marketing Manager | 22.5h |
| 12 | 2.2 | Order samples to give away |  | 7.5h | 2025-05-02 | 2025-05-05 | 11 | 1.59d | 0d | Marketing Assistant | 7.5h |
| 13 | 2.3 | Design Marketing Materials |  | 37.5h | 2025-05-05 | 2025-05-09 | 12 | 1.59d | 0d | Designer; Marketing Manager | 75h |
| 14 | 2.4 | Gather printing quotes |  | 15h | 2025-05-09 | 2025-05-13 | 13 | 1.59d | 0d | Admin Assistant; Marketing Assistant | 30h |
| 15 | 2.5 | Gather quotes for bag suppliers |  | 7.5h | 2025-05-13 | 2025-05-14 | 14 | 1.59d | 0d | Admin Assistant; Marketing Assistant | 15h |
| 16 | 2.6 | Choose successful printing bidder |  | 7.5h | 2025-05-14 | 2025-05-15 | 15 | 1.59d | 0d | Marketing Assistant | 7.5h |
| 17 | 2.7 | Order and print Marketing Materials |  | 22.5h | 2025-05-15 | 2025-05-20 | 16 | 1.59d | 0d | Corporate Printing Co | 22.5h |
| 18 | 2.8 | Order Sample Bags from Plastics printer |  | 5h | 2025-05-20 | 2025-05-21 | 17 | 1.59d | 0d | Corporate Printing Co | 5h |
| 19 | 2.9 | Delivery of Marketing Materials |  | 3.75h | 2025-05-21 | 2025-05-21 | 18 | 1.59d | 0d | ACME Couriers | 3.75h |
| 20 | 2.10 | Delivery of Samples |  | 3.75h | 2025-05-21 | 2025-05-21 | 19 | 1.59d | 0d | ACME Couriers | 3.75h |
| 21 | 2.11 | Collate Sample Bags |  | 22.5h | 2025-05-21 | 2025-05-26 | 20 | 1.59d | 0d | Marketing Assistant [300%] | 67.5h |
| 22 | 2.12 | Marketing Materials Complete | milestone | 0d | 2025-05-26 | 2025-05-26 | 21 | 1.59d | 0d |  |  |
| 23 | 3 | **Site Setup** |  | 5.62d | 2025-05-26 | 2025-06-03 |  | 1.59d |  |  | 375h |
| 24 | 3.1 | Exhibit staff OH&S Induction |  | 7.5h | 2025-05-26 | 2025-05-27 | 22 | 1.59d | 0d | OH&S Officer; Sales staff [1000%] | 82.5h |
| 25 | 3.2 | Issue Passes |  | 7.5h | 2025-05-27 | 2025-05-28 | 24 | 1.59d | 0d | Sales Manager; Sales staff | 15h |
| 26 | 3.3 | Deliver materials to Exhibition site |  | 7.5h | 2025-05-28 | 2025-05-29 | 25 | 1.59d | 0d | ACME Couriers | 7.5h |
| 27 | 3.4 | Move In |  | 22.5h | 2025-05-29 | 2025-06-03 | 26 | 1.59d | 0d | Project Manager; Sales Manager; Sales staff [1000%] | 270h |
| 28 | 3.5 | Site Setup Stage Complete | milestone | 0d | 2025-06-03 | 2025-06-03 | 27 | 1.59d | 0d |  |  |

| ID | WBS | Task | Type | Duration | Start | Finish | Predecessors | Total slack | Resources | Work |
| --- | --- | --- | --- | --- | --- | --- | --- | --- | --- | --- |
| 29 | 4 | **Exhibition** |  | 8.59d | 2025-06-03 | 2025-06-14 |  | 0d |  | 2640h |
| 30 | 4.1 | Exhibition |  | 11ed | 2025-06-03 | 2025-06-14 | 28 | 5.59d | Sales staff [1000%] | 2640h |
| 31 | 5 | **Post Exhibition Follow Up** |  | 7.88d | 2025-06-16 | 2025-06-25 |  | 0d |  | 274.5h |
| 32 | 5.1 | Move Out |  | 7.5h | 2025-06-16 | 2025-06-16 | 30 | 0d | Admin Assistant [200%]; Sales staff [500%] | 52.5h |
| 33 | 5.2 | Compile Feedback |  | 15h | 2025-06-16 | 2025-06-18 | 32 | 0d | Marketing Assistant; Marketing Manager | 30h |
| 34 | 5.3 | Compile Post Exhibition Report |  | 15h | 2025-06-18 | 2025-06-20 | 33 | 0d | Marketing Assistant; Marketing Manager; Sales Manager | 45h |
| 35 | 5.4 | Post Exhibition Review Meeting |  | 3h | 2025-06-20 | 2025-06-23 | 34 | 0d | Accountant; Marketing Manager; Project Manager; Sales Manager | 12h |
| 36 | 5.5 | Follow Up New Contacts |  | 22.5h | 2025-06-23 | 2025-06-25 | 35 | 0d | Sales Manager; Sales staff [500%] | 135h |
| 37 | 5.6 | Exhibition <Current Year> Complete | milestone | 0d | 2025-06-25 | 2025-06-25 | 36 | 0d |  |  |
