# Scheduling Options

Schedule from MS Project, 2025-04-07 to 2025-05-22, costs in $, A marks actual dates.
Office Renovation Project
Corporate Knowledge Management

## Calendars

- Standard: Mon-Fri 09:00-13:00, 14:00-17:00; Sat-Sun off. Exceptions (off unless hours are given): 2025-04-18 to 2025-04-21 (Easter), 2025-04-25 (Anzac Day), 2025-05-05 (Labor Day).

## Resources

| Resource | Group | Unit | Rate | Cost per use |
| --- | --- | --- | --- | --- |
| Carpenter | Contractor |  | 35 |  |
| Carpet | Materials | Lin Metre | 100 |  |
| Carpet Contractor | Contractor |  |  |  |
| Fit-out Consultant | Consultant |  | 65 | 50 |
| Furniture | Asset |  |  |  |
| Gyprock | Material | Sheet | 30 |  |
| Plaster | Material | Bag | 50 |  |
| IT Consultant | Contractor |  | 80 |  |
| Labourer | Contractor |  | 20 |  |
| Management | Staff |  | 100 |  |
| Network Cable & Points | Asset |  |  |  |
| PABX & Points | Asset |  |  |  |
| Paint | Material | Litre | 250 |  |
| Painter | Contractor |  | 35 |  |
| Personal Computers | Asset |  |  |  |
| Phones | Asset |  |  |  |
| Plasterer | Contractor |  | 35 |  |
| Project Manager | Staff |  | 80 |  |
| Staff | Staff |  | 50 |  |
| Telecommunications consultant | Consultant |  | 60 |  |
| Admin Assistant | Staff |  | 45 |  |

## Schedule

| ID | WBS | Task | Type | Duration | Start | Finish | Predecessors | Remaining | Baseline start | Baseline finish | Baseline duration | Total slack | Free slack | Resources | Work | Cost | Baseline cost |
| --- | --- | --- | --- | --- | --- | --- | --- | --- | --- | --- | --- | --- | --- | --- | --- | --- | --- |
| 1 | 1 | **Planning & Research** |  | 7.75d | 2025-04-07 09:00 | 2025-04-17 16:00 |  |  | 2025-04-07 09:00 | 2025-04-17 16:00 | 7.75d | 0.75d |  |  | 27h | 2,376 | 2,376 |
| 2 | 1.1 | Develop Requirements Documentation |  | 1d | 2025-04-07 09:00 | 2025-04-08 10:00 |  |  | 2025-04-07 09:00 | 2025-04-08 10:00 | 1d | 0.75d | 0d | Project Manager | 8h | 704 | 704 |
| 3 | 1.2 | Fit-Out Consultant Research |  | 0.5d | 2025-04-08 10:00 | 2025-04-08 15:00 | 2 |  | 2025-04-08 10:00 | 2025-04-08 15:00 | 0.5d | 0.75d | 0d | Project Manager | 4h | 352 | 352 |
| 4 | 1.3 | Telecommunications Consultant Research |  | 0.5d | 2025-04-08 15:00 | 2025-04-09 11:00 | 3 |  | 2025-04-08 15:00 | 2025-04-09 11:00 | 0.5d | 0.75d | 0d | Project Manager | 4h | 352 | 352 |
| 5 | 1.4 | IT Network Contractor Research |  | 0.5d | 2025-04-09 11:00 | 2025-04-09 16:00 | 4 |  | 2025-04-09 11:00 | 2025-04-09 16:00 | 0.5d | 0.75d | 0d | Project Manager | 4h | 352 | 352 |
| 6 | 1.5 | Building Contractors Research |  | 0.5d | 2025-04-09 16:00 | 2025-04-10 12:00 | 5 |  | 2025-04-09 16:00 | 2025-04-10 12:00 | 0.5d | 0.75d | 0d | Project Manager | 4h | 352 | 352 |
| 7 | 1.6 | Submit Requirements to Resources & Request Quotes |  | 2h | 2025-04-10 12:00 | 2025-04-10 15:00 | 6 |  | 2025-04-10 12:00 | 2025-04-10 15:00 | 2h | 0.75d | 0d | Project Manager | 2h | 176 | 176 |
| 8 | 1.7 | Quotes Received |  | 1h | 2025-04-17 15:00 | 2025-04-17 16:00 | 7FS+4.38d |  | 2025-04-17 15:00 | 2025-04-17 16:00 | 1h | 0.75d | 0d | Project Manager | 1h | 88 | 88 |
| 9 | 1.8 | Planning & Research Complete | milestone | 0d | 2025-04-17 16:00 | 2025-04-17 16:00 | 8 |  | 2025-04-17 16:00 | 2025-04-17 16:00 | 0d | 0.75d | 0d |  |  |  |  |
| 10 | 2 | **Management Approval** |  | 2.25d | 2025-04-17 16:00 | 2025-04-24 12:00 |  |  | 2025-04-17 16:00 | 2025-04-24 12:00 | 2.25d | 0.75d |  |  | 19h | 1,684 | 1,684 |
| 11 | 2.1 | Consolidate Quotes and develop proposal |  | 2d | 2025-04-17 16:00 | 2025-04-24 10:00 | 9 |  | 2025-04-17 16:00 | 2025-04-24 10:00 | 2d | 0.75d | 0d | Project Manager | 16h | 1,408 | 1,408 |
| 12 | 2.2 | Develop Project Plan & Durations |  | 1h | 2025-04-24 10:00 | 2025-04-24 11:00 | 11 |  | 2025-04-24 10:00 | 2025-04-24 11:00 | 1h | 0.75d | 0d | Project Manager | 1h | 88 | 88 |
| 13 | 2.3 | Submit Project Plan & Costs to Management |  | 1h | 2025-04-24 11:00 | 2025-04-24 12:00 | 12 |  | 2025-04-24 11:00 | 2025-04-24 12:00 | 1h | 0.75d | 0d | Project Manager; Management | 2h | 188 | 188 |
| 14 | 2.4 | Management Approval Received | milestone | 0d | 2025-04-24 12:00 | 2025-04-24 12:00 | 13 |  | 2025-04-24 12:00 | 2025-04-24 12:00 | 0d | 0.75d | 0d |  |  |  |  |
| 15 | 3 | **Refit Office** |  | 15.5d | 2025-04-24 12:00 A | 2025-05-22 10:00 |  | 15.5d | 2025-04-24 12:00 | 2025-05-22 10:00 | 15.5d | 0d |  |  | 120h | 77,313 | 77,313 |
| 16 | 3.1 | Appoint Resources |  | 2h | 2025-04-24 12:00 | 2025-04-24 15:00 | 14 |  | 2025-04-24 12:00 | 2025-04-24 15:00 | 2h | 0.75d | 0d | Project Manager | 2h | 176 | 176 |
| 17 | 3.2 | Staff Briefing |  | 1h | 2025-04-24 15:00 | 2025-04-24 16:00 | 16 |  | 2025-04-24 15:00 | 2025-04-24 16:00 | 1h | 0.75d | 0d | Project Manager; Staff [700%] | 8h | 438 | 438 |
| 18 | 3.3 | **Fit-Out Consultations** |  | 0.88d | 2025-04-24 16:00 | 2025-04-28 16:00 |  |  | 2025-04-24 16:00 | 2025-04-28 16:00 | 0.88d | 0.75d |  |  | 14h | 1,271 | 1,271 |
| 19 | 3.3.1 | Office Space / Structure Plan |  | 0.5d | 2025-04-24 16:00 | 2025-04-28 12:00 | 17 |  | 2025-04-24 16:00 | 2025-04-28 12:00 | 0.5d | 0.75d | 0d | Fit-out Consultant; Project Manager | 8h | 662 | 662 |
| 20 | 3.3.2 | Select & Order Carpet |  | 1h | 2025-04-28 12:00 | 2025-04-28 13:00 | 19 |  | 2025-04-28 12:00 | 2025-04-28 13:00 | 1h | 0.75d | 0d | Fit-out Consultant; Project Manager | 2h | 203 | 203 |
| 21 | 3.3.3 | Select & Order Paint |  | 1h | 2025-04-28 14:00 | 2025-04-28 15:00 | 20 |  | 2025-04-28 14:00 | 2025-04-28 15:00 | 1h | 0.75d | 0d | Fit-out Consultant; Project Manager | 2h | 203 | 203 |
| 22 | 3.3.4 | Select & Order Office Furniture |  | 1h | 2025-04-28 15:00 | 2025-04-28 16:00 | 21 |  | 2025-04-28 15:00 | 2025-04-28 16:00 | 1h | 0.75d | 0d | Fit-out Consultant; Project Manager | 2h | 203 | 203 |
| 23 | 3.4 | **Telecommuncations Consultations** |  | 0.62d | 2025-04-28 16:00 | 2025-04-29 13:00 |  |  | 2025-04-28 16:00 | 2025-04-29 13:00 | 0.62d | 0.75d |  |  | 9h | 680 | 680 |
| 24 | 3.4.1 | Design Telephone Access Points Map |  | 0.5d | 2025-04-28 16:00 | 2025-04-29 12:00 | 22 |  | 2025-04-28 16:00 | 2025-04-29 12:00 | 0.5d | 0.75d | 0d | Project Manager; Telecommunications consultant | 8h | 592 | 592 |
| 25 | 3.4.2 | Select & Order New PABX |  | 1h | 2025-04-29 12:00 | 2025-04-29 13:00 | 24 |  | 2025-04-29 12:00 | 2025-04-29 13:00 | 1h | 0.75d | 0d | Project Manager | 1h | 88 | 88 |

| ID | WBS | Task | Type | Duration | Start | Finish | Predecessors | Complete | Remaining | Baseline start | Baseline finish | Baseline duration | Total slack | Free slack | Resources | Work | Cost | Baseline cost |
| --- | --- | --- | --- | --- | --- | --- | --- | --- | --- | --- | --- | --- | --- | --- | --- | --- | --- | --- |
| 26 | 3.5 | **IT Networking Consultations** |  | 6.12d | 2025-04-29 14:00 | 2025-05-09 13:00 |  |  |  | 2025-04-29 14:00 | 2025-05-09 13:00 | 6.12d | 0.75d |  |  | 18h | 21,488 | 21,488 |
| 27 | 3.5.1 | Design Network Access Points Map |  | 0.5d | 2025-04-29 14:00 | 2025-04-30 10:00 | 22, 25 |  |  | 2025-04-29 14:00 | 2025-04-30 10:00 | 0.5d | 0.75d | 0d | IT Consultant; Project Manager | 8h | 672 | 672 |
| 28 | 3.5.2 | Select & Order New PCs |  | 1h | 2025-04-30 10:00 | 2025-04-30 11:00 | 27 |  |  | 2025-04-30 10:00 | 2025-04-30 11:00 | 1h | 0.75d | 0d | Project Manager | 1h | 88 | 88 |
| 29 | 3.5.3 | New PCs Arrive |  | 1h | 2025-05-08 11:00 | 2025-05-08 12:00 | 28FS+4.38d |  |  | 2025-05-08 11:00 | 2025-05-08 12:00 | 1h | 0.75d | 0d | Project Manager | 1h | 20,088 | 20,088 |
| 30 | 3.5.4 | Configure SOE on PCs |  | 1d | 2025-05-08 12:00 | 2025-05-09 13:00 | 29 |  |  | 2025-05-08 12:00 | 2025-05-09 13:00 | 1d | 0.75d | 0d | IT Consultant | 8h | 640 | 640 |
| 31 | 3.6 | **Restructure Office** |  | 14.12d | 2025-04-29 06:00 A | 2025-05-22 10:00 |  |  | 14.12d | 2025-04-29 06:00 | 2025-05-22 10:00 | 14.12d | 0d |  |  | 69h | 53,260 | 53,260 |
| 32 | 3.6.1 | Erect New Walls |  | 7h | 2025-04-29 06:00 | 2025-05-01 07:00 | 22 |  |  | 2025-04-29 06:00 | 2025-05-01 07:00 | 7h | 2.62d | 0d | Carpenter [200%] | 14h | 490 | 490 |
| 33 | 3.6.2 | Gyprock, Plaster & Finish |  | 14h | 2025-05-01 07:00 | 2025-05-05 08:00 | 32 |  |  | 2025-05-01 07:00 | 2025-05-05 08:00 | 14h | 2.62d | 2.25d | Plasterer | 14h | 10,490 | 10,490 |
| 34 | 3.6.3 | Install Network Points |  | 5h | 2025-05-09 14:00 | 2025-05-12 11:00 | 33FS+1ed, 30 |  |  | 2025-05-09 14:00 | 2025-05-12 11:00 | 5h | 0.75d | 0d | IT Consultant | 5h | 400 | 400 |
| 35 | 3.6.4 | Install Phone Connections |  | 0.5d | 2025-05-09 14:00 | 2025-05-12 10:00 | 34SS |  |  | 2025-05-09 14:00 | 2025-05-12 10:00 | 0.5d | 0.75d |  | Telecommunications consultant | 4h | 800 | 800 |
| 36 | 3.6.5 | Re-Paint |  | 1d | 2025-05-13 06:00 | 2025-05-15 08:00 | 35 |  |  | 2025-05-13 06:00 | 2025-05-15 08:00 | 1d | 0d |  | Paint [100 Litre]; Painter | 8h | 25,280 | 25,280 |
| 37 | 3.6.6 | Carpet |  | 1d | 2025-05-16 08:00 | 2025-05-17 15:00 | 36FS+1ed |  |  | 2025-05-16 08:00 | 2025-05-17 15:00 | 1d | 0d |  | Carpet [100 Lin Metre]; Carpet Contractor | 8h | 15,000 | 15,000 |
| 38 | 3.6.7 | Install New Furniture |  | 1d | 2025-05-19 06:00 | 2025-05-21 08:00 | 37 |  |  | 2025-05-19 06:00 | 2025-05-21 08:00 | 1d | 0d |  | Labourer | 8h | 160 | 160 |
| 39 | 3.6.8 | Install New PCs |  | 1d | 2025-05-21 09:00 | 2025-05-22 10:00 | 38 |  |  | 2025-05-21 09:00 | 2025-05-22 10:00 | 1d | 0d |  | IT Consultant | 8h | 640 | 640 |
| 40 | 3.6.9 | Refit Office Complete | milestone | 0d | 2025-05-16 10:00 A | 2025-05-16 10:00 A | 39 | 100% |  | 2025-05-16 10:00 | 2025-05-16 10:00 | 0d |  |  |  |  |  |  |
| 41 | 4 | **Office Move** |  | 7.5d | 2025-05-08 12:00 | 2025-05-20 17:00 |  |  |  | 2025-05-08 12:00 | 2025-05-20 17:00 | 7.5d | 1d |  |  | 405h | 20,440 | 20,440 |
| 42 | 4.1 | Order packing boxes |  | 1h | 2025-05-08 12:00 | 2025-05-08 13:00 | 29 |  |  | 2025-05-08 12:00 | 2025-05-08 13:00 | 1h | 5.88d | 4.88d | Project Manager | 1h | 88 | 88 |
| 43 | 4.2 | Staff Pack |  | 0.5d | 2025-05-16 10:00 | 2025-05-16 15:00 | 40, 42 |  |  | 2025-05-16 10:00 | 2025-05-16 15:00 | 0.5d | 1d | 0d | Project Manager; Staff [2000%] | 84h | 4,352 | 4,352 |
| 44 | 4.3 | Staff Move |  | 2d | 2025-05-16 15:00 | 2025-05-20 17:00 | 43 |  |  | 2025-05-16 15:00 | 2025-05-20 17:00 | 2d | 1d | 0d | Staff [2000%] | 320h | 16,000 | 16,000 |
| 45 | 4.4 | Office Move Complete | milestone | 0d | 2025-05-20 17:00 | 2025-05-20 17:00 | 44 |  |  | 2025-05-20 17:00 | 2025-05-20 17:00 | 0d | 1d |  |  |  |  |  |
