# Sub 1

Schedule from MS Project, 2025-04-07 to 2025-04-17, 7 hours a day, costs in $.
Office Renovation Project
Corporate Knowledge Management

## Calendars

- Standard: Mon-Fri 09:00-13:00, 14:00-17:00; Sat-Sun off.

## Resources

| Resource | Group | Unit | Rate | Cost per use |
| --- | --- | --- | --- | --- |
| Carpenter | Contractor |  | 35 |  |
| Carpet | Materials | Lin Metre | 100 |  |
| Carpet Contractor | Contractor |  |  |  |
| Fit-out Consultant | Consultant |  | 65 | 50 |
| Furniture | Asset |  |  |  |
| Gyprock | Material | Sheet | 30 |  |
| Plaster | Material | Bag | 50 |  |
| IT Consultant | Contractor |  | 80 |  |
| Labourer | Contractor |  | 20 |  |
| Management | Staff |  | 100 |  |
| Network Cable & Points | Asset |  |  |  |
| PABX & Points | Asset |  |  |  |
| Paint | Material | Litre | 250 |  |
| Painter | Contractor |  | 35 |  |
| Personal Computers | Asset |  |  |  |
| Phones | Asset |  |  |  |
| Plasterer | Contractor |  | 35 |  |
| Project Manager | Staff |  | 80 |  |
| Staff | Staff |  | 50 |  |
| Telecommunications consultant | Consultant |  | 60 |  |
| Admin Assistant | Staff |  | 45 |  |

## Schedule

| ID | WBS | Task | Type | Duration | Start | Finish | Predecessors | Baseline start | Baseline finish | Baseline duration | Total slack | Deadline | Resources | Work | Cost | Baseline cost |
| --- | --- | --- | --- | --- | --- | --- | --- | --- | --- | --- | --- | --- | --- | --- | --- | --- |
| 1 | 1 | **Planning & Research** |  | 8.43d | 2025-04-07 09:00 | 2025-04-17 12:00 |  | 2011-04-04 09:00 | 2011-04-14 12:00 | 8.43d | 0d |  |  | 24h | 2,112 | 1,920 |
| 2 | 1.1 | Develop Requirements Documentation |  | 1d | 2025-04-07 09:00 | 2025-04-07 17:00 |  | 2011-04-04 09:00 | 2011-04-04 17:00 | 1d | 0d | 2025-04-07 17:00 | Project Manager | 7h | 616 | 560 |
| 3 | 1.2 | Fit-Out Consultant Research |  | 0.5d | 2025-04-08 09:00 | 2025-04-08 12:30 | 2 | 2011-04-05 09:00 | 2011-04-05 12:30 | 0.5d | 0d |  | Project Manager | 3.5h | 308 | 280 |
| 4 | 1.3 | Telecommunications Consultant Research |  | 0.5d | 2025-04-08 12:30 | 2025-04-08 17:00 | 3 | 2011-04-05 12:30 | 2011-04-05 17:00 | 0.5d | 0d |  | Project Manager | 3.5h | 308 | 280 |
| 5 | 1.4 | IT Network Contractor Research |  | 0.5d | 2025-04-09 09:00 | 2025-04-09 12:30 | 4 | 2011-04-06 09:00 | 2011-04-06 12:30 | 0.5d | 0d |  | Project Manager | 3.5h | 308 | 280 |
| 6 | 1.5 | Building Contractors Research |  | 0.5d | 2025-04-09 12:30 | 2025-04-09 17:00 | 5 | 2011-04-06 12:30 | 2011-04-06 17:00 | 0.5d | 0d |  | Project Manager | 3.5h | 308 | 280 |
| 7 | 1.6 | Submit Requirements to Resources & Request Quotes |  | 2h | 2025-04-10 09:00 | 2025-04-10 11:00 | 6 | 2011-04-07 09:00 | 2011-04-07 11:00 | 2h | 0d |  | Project Manager | 2h | 176 | 160 |
| 8 | 1.7 | Quotes Received |  | 1h | 2025-04-17 11:00 | 2025-04-17 12:00 | 7FS+5d | 2011-04-14 11:00 | 2011-04-14 12:00 | 1h | 0d |  | Project Manager | 1h | 88 | 80 |
| 9 | 1.8 | Planning & Research Complete | milestone | 0d | 2025-04-17 12:00 | 2025-04-17 12:00 | 8 | 2011-04-14 12:00 | 2011-04-14 12:00 | 0d | 0d |  |  |  |  |  |
