# CKM Office Renovation

Schedule from MS Project, 2025-04-07 to 2025-05-31, 7 hours a day, costs in $.
Office Renovation Project
Corporate Knowledge Management

## Calendars

- Standard: Mon-Fri 09:00-13:00, 14:00-17:00; Sat-Sun off.

## Resources

| Resource | Group | Unit | Rate | Cost per use |
| --- | --- | --- | --- | --- |
| Carpenter | Contractor |  | 35 |  |
| Carpet | Materials | Lin Metre | 100 |  |
| Carpet Contractor | Contractor |  |  |  |
| Fit-out Consultant | Consultant |  | 65 | 50 |
| Furniture | Asset |  |  |  |
| Gyprock | Material | Sheet | 30 |  |
| Plaster | Material | Bag | 50 |  |
| IT Consultant | Contractor |  | 80 |  |
| Labourer | Contractor |  | 20 |  |
| Management | Staff |  | 100 |  |
| Network Cable & Points | Asset |  |  |  |
| PABX & Points | Asset |  |  |  |
| Paint | Material | Litre | 250 |  |
| Painter | Contractor |  | 35 |  |
| Personal Computers | Asset |  |  |  |
| Phones | Asset |  |  |  |
| Plasterer | Contractor |  | 35 |  |
| Project Manager | Staff |  | 88 |  |
| Staff | Staff |  | 50 |  |
| Telecommunications consultant | Consultant |  | 60 |  |
| Admin Assistant | Staff |  | 45 |  |

## Schedule

| ID | WBS | Task | Type | Duration | Start | Finish | Predecessors | Baseline start | Baseline finish | Baseline duration | Total slack | Resources | Work | Cost | Baseline cost |
| --- | --- | --- | --- | --- | --- | --- | --- | --- | --- | --- | --- | --- | --- | --- | --- |
| 1 | 1 | **Planning & Research** |  | 12d | 2025-04-07 | 2025-04-22 |  | 2011-04-04 | 2011-04-14 | 8.43d | 0d |  | 49h | 4,312 | 1,920 |
| 2 | 1.1 | Develop Requirements Documentation |  | 1d | 2025-04-07 | 2025-04-07 |  | 2011-04-04 | 2011-04-04 | 1d | 0d | Project Manager | 7h | 616 | 560 |
| 3 | 1.2 | Fit-Out Consultant Research |  | 1d | 2025-04-08 | 2025-04-08 | 2 | 2011-04-05 | 2011-04-05 | 0.5d | 0d | Project Manager | 7h | 616 | 280 |
| 4 | 1.3 | Telecommunications Consultant Research |  | 1d | 2025-04-09 | 2025-04-09 | 3 | 2011-04-05 | 2011-04-05 | 0.5d | 0d | Project Manager | 7h | 616 | 280 |
| 5 | 1.4 | IT Network Contractor Research |  | 1d | 2025-04-10 | 2025-04-10 | 4 | 2011-04-06 | 2011-04-06 | 0.5d | 0d | Project Manager | 7h | 616 | 280 |
| 6 | 1.5 | Building Contractors Research |  | 1d | 2025-04-11 | 2025-04-11 | 5 | 2011-04-06 | 2011-04-06 | 0.5d | 0d | Project Manager | 7h | 616 | 280 |
| 7 | 1.6 | Submit Requirements to Resources & Request Quotes |  | 1d | 2025-04-14 | 2025-04-14 | 6 | 2011-04-07 | 2011-04-07 | 2h | 0d | Project Manager | 7h | 616 | 160 |
| 8 | 1.7 | Quotes Received |  | 1d | 2025-04-22 | 2025-04-22 | 7FS+5d | 2011-04-14 | 2011-04-14 | 1h | 0d | Project Manager | 7h | 616 | 80 |
| 9 | 1.8 | Planning & Research Complete | milestone | 0d | 2025-04-22 | 2025-04-22 | 8 | 2011-04-14 | 2011-04-14 | 0d | 0d |  |  |  |  |
| 10 | 2 | **Management Approval** |  | 3.5d | 2025-04-23 | 2025-04-28 |  | 2011-04-14 | 2011-04-15 | 1.29d | 0d |  | 31.5h | 2,856 | 820 |
| 11 | 2.1 | Consolidate Quotes and develop proposal |  | 1.5d | 2025-04-23 | 2025-04-24 | 9 | 2011-04-14 | 2011-04-15 | 1d | 0d | Project Manager | 10.5h | 924 | 560 |
| 12 | 2.2 | Develop Project Plan & Durations |  | 1d | 2025-04-24 | 2025-04-25 | 11 | 2011-04-15 | 2011-04-15 | 1h | 0d | Project Manager | 7h | 616 | 80 |
| 13 | 2.3 | Submit Project Plan & Costs to Management |  | 1d | 2025-04-25 | 2025-04-28 | 12 | 2011-04-15 | 2011-04-15 | 1h | 0d | Project Manager; Management | 14h | 1,316 | 180 |
| 14 | 2.4 | Management Approval Received | milestone | 0d | 2025-04-28 | 2025-04-28 | 13 | 2011-04-15 | 2011-04-15 | 0d | 0d |  |  |  |  |
| 15 | 3 | **Refit Office** |  | 22.5d | 2025-04-28 | 2025-05-28 |  | 2011-04-15 | 2011-05-11 | 15.29d | 0d |  | 225.5h | 84,705 | 76,607.5 |
| 16 | 3.1 | Appoint Resources |  | 1d | 2025-04-28 | 2025-04-29 | 14 | 2011-04-15 | 2011-04-15 | 2h | 0d | Project Manager | 7h | 616 | 160 |
| 17 | 3.2 | Staff Briefing |  | 1d | 2025-04-29 | 2025-04-30 | 16 | 2011-04-18 | 2011-04-18 | 1h | 0d | Project Manager; Staff [700%] | 56h | 3,066 | 430 |
| 18 | 3.3 | **Fit-Out Consultations** |  | 4d | 2025-04-30 | 2025-05-06 |  | 2011-04-18 | 2011-04-19 | 0.93d | 0d |  | 56h | 4,484 | 1,142.5 |
| 19 | 3.3.1 | Office Space / Structure Plan |  | 1d | 2025-04-30 | 2025-05-01 | 17 | 2011-04-18 | 2011-04-18 | 0.5d | 0d | Fit-out Consultant; Project Manager | 14h | 1,121 | 557.5 |
| 20 | 3.3.2 | Select & Order Carpet |  | 1d | 2025-05-01 | 2025-05-02 | 19 | 2011-04-18 | 2011-04-18 | 1h | 0d | Fit-out Consultant; Project Manager | 14h | 1,121 | 195 |
| 21 | 3.3.3 | Select & Order Paint |  | 1d | 2025-05-02 | 2025-05-05 | 20 | 2011-04-18 | 2011-04-18 | 1h | 0d | Fit-out Consultant; Project Manager | 14h | 1,121 | 195 |
| 22 | 3.3.4 | Select & Order Office Furniture |  | 1d | 2025-05-05 | 2025-05-06 | 21 | 2011-04-18 | 2011-04-19 | 1h | 0d | Fit-out Consultant; Project Manager | 14h | 1,121 | 195 |
| 23 | 3.4 | **Telecommuncations Consultations** |  | 1.5d | 2025-05-06 | 2025-05-07 |  | 2011-04-19 | 2011-04-19 | 0.64d | 0d |  | 14h | 1,134 | 570 |
| 24 | 3.4.1 | Design Telephone Access Points Map |  | 0.5d | 2025-05-06 | 2025-05-06 | 22 | 2011-04-19 | 2011-04-19 | 0.5d | 0d | Project Manager; Telecommunications consultant | 7h | 518 | 490 |
| 25 | 3.4.2 | Select & Order New PABX |  | 1d | 2025-05-07 | 2025-05-07 | 24 | 2011-04-19 | 2011-04-19 | 1h | 0d | Project Manager | 7h | 616 | 80 |

| ID | WBS | Task | Type | Duration | Start | Finish | Predecessors | Baseline start | Baseline finish | Baseline duration | Total slack | Free slack | Resources | Work | Cost | Baseline cost |
| --- | --- | --- | --- | --- | --- | --- | --- | --- | --- | --- | --- | --- | --- | --- | --- | --- |
| 26 | 3.5 | **IT Networking Consultations** |  | 8.5d | 2025-05-08 | 2025-05-20 |  | 2011-04-19 | 2011-05-03 | 6.79d | 0d |  |  | 28h | 22,380 | 21,280 |
| 27 | 3.5.1 | Design Network Access Points Map |  | 0.5d | 2025-05-08 | 2025-05-08 | 22, 25 | 2011-04-19 | 2011-04-20 | 0.5d | 0d |  | IT Consultant; Project Manager | 7h | 588 | 560 |
| 28 | 3.5.2 | Select & Order New PCs |  | 1d | 2025-05-08 | 2025-05-09 | 27 | 2011-04-20 | 2011-04-20 | 1h | 0d |  | Project Manager | 7h | 616 | 80 |
| 29 | 3.5.3 | New PCs Arrive |  | 1d | 2025-05-16 | 2025-05-19 | 28FS+5d | 2011-04-29 | 2011-04-29 | 1h | 0d |  | Project Manager | 7h | 20,616 | 20,080 |
| 30 | 3.5.4 | Configure SOE on PCs |  | 1d | 2025-05-19 | 2025-05-20 | 29 | 2011-04-29 | 2011-05-03 | 1d | 0d |  | IT Consultant | 7h | 560 | 560 |
| 31 | 3.6 | **Restructure Office** |  | 16d | 2025-05-07 | 2025-05-28 |  | 2011-04-20 | 2011-05-11 | 13d | 0.5d |  |  | 64.5h | 53,025 | 53,025 |
| 32 | 3.6.1 | Erect New Walls |  | 7h | 2025-05-07 | 2025-05-09 | 22 | 2011-04-20 | 2011-04-26 | 7h | 4d | 0d | Carpenter [200%] | 14h | 490 | 490 |
| 33 | 3.6.2 | Gyprock, Plaster & Finish |  | 14h | 2025-05-09 | 2025-05-13 | 32 | 2011-04-26 | 2011-04-30 | 14h | 4d |  | Plasterer | 14h | 10,490 | 10,490 |
| 34 | 3.6.3 | Install Network Points |  | 5h | 2025-05-20 | 2025-05-21 | 33FS+1d, 30 | 2011-05-03 | 2011-05-04 | 5h | 0d |  | IT Consultant | 5h | 400 | 400 |
| 35 | 3.6.4 | Install Phone Connections |  | 0.5d | 2025-05-20 | 2025-05-20 | 34SS | 2011-05-03 | 2011-05-03 | 0.5d | 0d |  | Telecommunications consultant | 3.5h | 700 | 700 |
| 36 | 3.6.5 | Re-Paint |  | 1d | 2025-05-21 | 2025-05-23 | 35 | 2011-05-04 | 2011-05-06 | 1d | 0d |  | Paint [100 Litre]; Painter | 7h | 25,245 | 25,245 |
| 37 | 3.6.6 | Carpet |  | 1d | 2025-05-24 | 2025-05-24 | 36FS+1ed | 2011-05-07 | 2011-05-07 | 1d | 0d |  | Carpet [100 Lin Metre]; Carpet Contractor | 7h | 15,000 | 15,000 |
| 38 | 3.6.7 | Install New Furniture |  | 1d | 2025-05-26 | 2025-05-28 | 37 | 2011-05-09 | 2011-05-11 | 1d | 0d |  | Labourer | 7h | 140 | 140 |
| 39 | 3.6.8 | Install New PCs |  | 1d | 2025-05-28 | 2025-05-28 | 38 | 2011-05-11 | 2011-05-11 | 1d | 0.5d | 0d | IT Consultant | 7h | 560 | 560 |
| 40 | 3.6.9 | Refit Office Complete | milestone | 0d | 2025-05-28 | 2025-05-28 | 39 | 2011-05-11 | 2011-05-11 | 0d | 0.5d | 0d |  |  |  |  |
| 41 | 4 | **Office Move** |  | 9.5d | 2025-05-19 | 2025-05-31 |  | 2011-04-29 | 2011-05-16 | 10.5d | 0d |  |  | 221.5h | 11,036 | 11,028 |
| 42 | 4.1 | Order packing boxes |  | 1h | 2025-05-19 | 2025-05-19 | 29 | 2011-04-29 | 2011-04-29 | 1h | 7.86d | 7.36d | Project Manager | 1h | 88 | 80 |
| 43 | 4.2 | Staff Pack |  | 0.5d | 2025-05-29 | 2025-05-29 | 40, 42 | 2011-05-12 | 2011-05-12 | 0.5d | 0.5d | 0d | Project Manager; Staff [2000%] | 73.5h | 3,808 | 3,808 |
| 44 | 4.3 | Staff Move |  | 2d | 2025-05-29 | 2025-05-31 | 43 | 2011-05-12 | 2011-05-14 | 2d | 0d |  | Staff [2000%]; Labourer | 147h | 7,140 | 7,140 |
| 45 | 4.4 | Office Move Complete | milestone | 0d | 2025-05-31 | 2025-05-31 | 44 | 2011-05-16 | 2011-05-16 | 0d | 0d |  |  |  |  |  |
