# CKM Office Renovation

Schedule from MS Project, 2025-04-07 to 2025-06-09, 7 hours a day.
Office Renovation Project
Corporate Knowledge Management

## Calendars

- Standard: Mon-Fri 09:00-13:00, 14:00-17:00; Sat-Sun off. Exceptions (off unless hours are given): 2025-04-18 to 2025-04-21 (Easter), 2025-04-25 (Anzac Day), 2025-05-05 (Labor Day).

## Schedule

| ID | WBS | Task | Type | Duration | Start | Finish | Predecessors | Total slack | Free slack |
| --- | --- | --- | --- | --- | --- | --- | --- | --- | --- |
| 1 | 1 | **Planning & Research** |  | 15.5d | 2025-04-07 | 2025-05-01 |  | 0d |  |
| 2 | 1.1 | Develop Requirements Documentation |  | 1d | 2025-04-07 | 2025-04-07 |  | 0d |  |
| 3 | 1.2 | Fit-Out Consultant Research |  | 2d | 2025-04-08 | 2025-04-09 | 2 | 0d |  |
| 4 | 1.3 | Telecommunications Consultant Research |  | 2d | 2025-04-10 | 2025-04-11 | 3 | 0d |  |
| 5 | 1.4 | IT Network Contractor Research |  | 2d | 2025-04-14 | 2025-04-15 | 4 | 0d |  |
| 6 | 1.5 | Building Contractors Research |  | 2d | 2025-04-16 | 2025-04-17 | 5 | 0d |  |
| 7 | 1.6 | Submit Requirements to Resources & Request Quotes |  | 1d | 2025-04-22 | 2025-04-22 | 6 | 0d |  |
| 8 | 1.7 | Quotes Received |  | 0.5d | 2025-05-01 | 2025-05-01 | 7FS+5d | 0d |  |
| 9 | 1.8 | Planning & Research Complete | milestone | 0d | 2025-05-01 | 2025-05-01 | 8 | 0d |  |
| 10 | 2 | **Management Approval** |  | 4.14d | 2025-05-01 | 2025-05-08 |  | 0d |  |
| 11 | 2.1 | Consolidate Quotes and develop proposal |  | 2d | 2025-05-01 | 2025-05-06 | 9 | 0d |  |
| 12 | 2.2 | Develop Project Plan & Durations |  | 2d | 2025-05-06 | 2025-05-08 | 11 | 0d |  |
| 13 | 2.3 | Submit Project Plan & Costs to Management |  | 1h | 2025-05-08 | 2025-05-08 | 12 | 0d |  |
| 14 | 2.4 | Management Approval Received | milestone | 0d | 2025-05-08 | 2025-05-08 | 13 | 0d |  |
| 15 | 3 | **Refit Office** |  | 20.07d | 2025-05-08 | 2025-06-05 |  | 0d |  |
| 16 | 3.1 | Appoint Resources |  | 1d | 2025-05-08 | 2025-05-09 | 14 | 0d |  |
| 17 | 3.2 | Staff Briefing |  | 1h | 2025-05-09 | 2025-05-09 | 16 | 0d |  |
| 18 | 3.3 | **Fit-Out Consultations** |  | 2.5d | 2025-05-09 | 2025-05-14 |  | 0d |  |
| 19 | 3.3.1 | Office Space / Structure Plan |  | 1d | 2025-05-09 | 2025-05-12 | 17 | 0d |  |
| 20 | 3.3.2 | Select & Order Carpet |  | 0.5d | 2025-05-12 | 2025-05-13 | 19 | 0d |  |
| 21 | 3.3.3 | Select & Order Paint |  | 0.5d | 2025-05-13 | 2025-05-13 | 20 | 0d |  |
| 22 | 3.3.4 | Select & Order Office Furniture |  | 0.5d | 2025-05-13 | 2025-05-14 | 21 | 0d |  |
| 23 | 3.4 | **Telecommuncations Consultations** |  | 2d | 2025-05-14 | 2025-05-16 |  | 16.43d |  |
| 24 | 3.4.1 | Design Telephone Access Points Map |  | 1d | 2025-05-14 | 2025-05-15 | 22 | 16.43d | 0d |
| 25 | 3.4.2 | Select & Order New PABX |  | 1d | 2025-05-15 | 2025-05-16 | 24 | 16.43d |  |

| ID | WBS | Task | Type | Duration | Start | Finish | Predecessors | Total slack |
| --- | --- | --- | --- | --- | --- | --- | --- | --- |
| 26 | 3.5 | **IT Networking Consultations** |  | 8.14d | 2025-05-14 | 2025-05-26 |  | 0d |
| 27 | 3.5.1 | Design Network Access Points Map |  | 1d | 2025-05-14 | 2025-05-15 | 22 | 0d |
| 28 | 3.5.2 | Select & Order New PCs |  | 1d | 2025-05-15 | 2025-05-16 | 27 | 0d |
| 29 | 3.5.3 | New PCs Arrive |  | 1h | 2025-05-23 | 2025-05-23 | 28FS+5d | 0d |
| 30 | 3.5.4 | Configure SOE on PCs |  | 1d | 2025-05-23 | 2025-05-26 | 29 | 0d |
| 31 | 3.6 | **Restructure Office** |  | 8.29d | 2025-05-26 | 2025-06-05 |  | 0d |
| 32 | 3.6.1 | Erect New Walls |  | 7h | 2025-05-26 | 2025-05-27 | 30 | 0d |
| 33 | 3.6.2 | Gyprock, Plaster & Finish |  | 7h | 2025-05-27 | 2025-05-28 | 32 | 0d |
| 34 | 3.6.3 | Install Network Points |  | 5h | 2025-05-29 | 2025-05-30 | 33FS+1d | 0d |
| 35 | 3.6.4 | Install Phone Connections |  | 2h | 2025-05-29 | 2025-05-29 | 34SS | 0d |
| 36 | 3.6.5 | Re-Paint |  | 1d | 2025-05-29 | 2025-05-30 | 35 | 0d |
| 37 | 3.6.6 | Carpet |  | 1d | 2025-06-02 | 2025-06-03 | 36FS+1d | 0d |
| 38 | 3.6.7 | Install New Furniture |  | 1d | 2025-06-03 | 2025-06-04 | 37 | 0d |
| 39 | 3.6.8 | Install New PCs |  | 1d | 2025-06-04 | 2025-06-05 | 38 | 0d |
| 40 | 3.6.9 | Refit Office Complete | milestone | 0d | 2025-06-05 | 2025-06-05 | 39 | 0d |
| 41 | 4 | **Office Move** |  | 3d | 2025-06-04 | 2025-06-09 |  | 0d |
| 42 | 4.1 | Order packing boxes |  | 1h | 2025-06-04 | 2025-06-04 | 38 | 2.86d |
| 43 | 4.2 | Staff Pack |  | 1d | 2025-06-05 | 2025-06-06 | 40 | 0d |
| 44 | 4.3 | Staff Move |  | 1d | 2025-06-06 | 2025-06-09 | 43 | 0d |
| 45 | 4.4 | Office Move Complete | milestone | 0d | 2025-06-09 | 2025-06-09 | 44 | 0d |
